# Earned Value

How a schedule from MS Project changed from version to version. A marks actual dates.

## Version 1 (saved 2018-01-08, file Comparison Version 1.mpp)

| ID | Task | Duration | Start | Finish | Predecessors | Total float |
| --- | --- | --- | --- | --- | --- | --- |
| 1 | Planning Stage | 6w | 2018-05-07 | 2018-06-15 |  | 0d |
| 2 | Footings | 3d | 2018-06-18 | 2018-06-20 | 1 | 0d |
| 3 | External Plumbing | 1d | 2018-06-21 | 2018-06-21 | 2 | 0d |
| 4 | Pour foundation slab | 1d | 2018-06-22 | 2018-06-22 | 3 | 0d |
| 5 | Slab down | 0d | 2018-06-23 | 2018-06-23 | 4FS+24eh | 0d |
| 6 | Erect house frame | 5d | 2018-06-25 | 2018-06-29 | 5 | 0d |
| 7 | Roofing tiles | 3d | 2018-07-02 | 2018-07-04 | 6 | 0d |
| 8 | Brick Walls | 5d | 2018-07-05 | 2018-07-11 | 7 | 0d |
| 9 | Fit Windows & Doors | 2d | 2018-07-12 | 2018-07-13 | 8 | 0d |
| 10 | Electrical Cables | 1d | 2018-07-16 | 2018-07-16 | 9 | 0d |
| 11 | Internal Plumbing | 1d | 2018-07-16 | 2018-07-16 | 10SS | 0d |
| 12 | Plaster Walls | 5d | 2018-07-17 | 2018-07-23 | 11 | 0d |
| 13 | Internal Doors and Trim | 4d | 2018-07-24 | 2018-07-27 | 12 | 0d |
| 14 | Install Kitchen | 2d | 2018-07-30 | 2018-07-31 | 13 | 0d |
| 15 | Install Bathroom | 2d | 2018-07-30 | 2018-07-31 | 14SS | 0d |
| 16 | Final Electrical Fittings | 2d | 2018-08-01 | 2018-08-02 | 15 | 0d |
| 17 | Final Plumbing Fittings | 2d | 2018-08-01 | 2018-08-02 | 16SS | 0d |
| 18 | Paint | 5d | 2018-08-03 | 2018-08-09 | 17 | 0d |
| 19 | Lock up | 0d | 2018-08-09 | 2018-08-09 | 18 | 0d |

## Version 2 (data date 2018-07-02, saved 2018-01-08, file Comparison Version 2.mpp)

Last finish stays 2018-08-09.

Changed:

| ID | Task | Other |
| --- | --- | --- |
| 1 | Planning Stage | baseline start none → 2011-04-04; baseline finish none → 2011-05-13 |
| 2 | Footings | baseline start none → 2011-05-16; baseline finish none → 2011-05-18 |
| 3 | External Plumbing | baseline start none → 2011-05-19; baseline finish none → 2011-05-19 |
| 4 | Pour foundation slab | baseline start none → 2011-05-20; baseline finish none → 2011-05-20 |
| 5 | Slab down | baseline start none → 2011-05-21; baseline finish none → 2011-05-21 |
| 6 | Erect house frame | baseline start none → 2011-05-23; baseline finish none → 2011-05-27 |
| 7 | Roofing tiles | baseline start none → 2011-05-30; baseline finish none → 2011-06-01 |
| 8 | Brick Walls | baseline start none → 2011-06-02; baseline finish none → 2011-06-08 |
| 9 | Fit Windows & Doors | baseline start none → 2011-06-09; baseline finish none → 2011-06-10 |
| 10 | Electrical Cables | baseline start none → 2011-06-13; baseline finish none → 2011-06-13 |
| 11 | Internal Plumbing | baseline start none → 2011-06-13; baseline finish none → 2011-06-13 |
| 12 | Plaster Walls | baseline start none → 2011-06-14; baseline finish none → 2011-06-20 |
| 13 | Internal Doors and Trim | baseline start none → 2011-06-21; baseline finish none → 2011-06-24 |
| 14 | Install Kitchen | baseline start none → 2011-06-27; baseline finish none → 2011-06-28 |
| 15 | Install Bathroom | baseline start none → 2011-06-27; baseline finish none → 2011-06-28 |
| 16 | Final Electrical Fittings | baseline start none → 2011-06-29; baseline finish none → 2011-06-30 |
| 17 | Final Plumbing Fittings | baseline start none → 2011-06-29; baseline finish none → 2011-06-30 |
| 18 | Paint | baseline start none → 2011-07-01; baseline finish none → 2011-07-07 |
| 19 | Lock up | baseline start none → 2011-07-07; baseline finish none → 2011-07-07 |

## Version 3 (saved 2018-01-08, file Earned Value.mpp)

Last finish stays 2018-08-09.

Changed:

| ID | Task | Other |
| --- | --- | --- |
| 1 | Planning Stage | baseline start 2011-04-04 → none; baseline finish 2011-05-13 → none |
| 2 | Footings | baseline start 2011-05-16 → none; baseline finish 2011-05-18 → none |
| 3 | External Plumbing | baseline start 2011-05-19 → none; baseline finish 2011-05-19 → none |
| 4 | Pour foundation slab | baseline start 2011-05-20 → none; baseline finish 2011-05-20 → none |
| 5 | Slab down | baseline start 2011-05-21 → none; baseline finish 2011-05-21 → none |
| 6 | Erect house frame | baseline start 2011-05-23 → none; baseline finish 2011-05-27 → none |
| 7 | Roofing tiles | baseline start 2011-05-30 → none; baseline finish 2011-06-01 → none |
| 8 | Brick Walls | baseline start 2011-06-02 → none; baseline finish 2011-06-08 → none |
| 9 | Fit Windows & Doors | baseline start 2011-06-09 → none; baseline finish 2011-06-10 → none |
| 10 | Electrical Cables | baseline start 2011-06-13 → none; baseline finish 2011-06-13 → none |
| 11 | Internal Plumbing | baseline start 2011-06-13 → none; baseline finish 2011-06-13 → none |
| 12 | Plaster Walls | baseline start 2011-06-14 → none; baseline finish 2011-06-20 → none |
| 13 | Internal Doors and Trim | baseline start 2011-06-21 → none; baseline finish 2011-06-24 → none |
| 14 | Install Kitchen | baseline start 2011-06-27 → none; baseline finish 2011-06-28 → none |
| 15 | Install Bathroom | baseline start 2011-06-27 → none; baseline finish 2011-06-28 → none |
| 16 | Final Electrical Fittings | baseline start 2011-06-29 → none; baseline finish 2011-06-30 → none |
| 17 | Final Plumbing Fittings | baseline start 2011-06-29 → none; baseline finish 2011-06-30 → none |
| 18 | Paint | baseline start 2011-07-01 → none; baseline finish 2011-07-07 → none |
| 19 | Lock up | baseline start 2011-07-07 → none; baseline finish 2011-07-07 → none |

## Version 4 (saved 2018-01-08, file House.mpp)

Last finish 2018-08-09 → 2018-08-02 (-7d).

Added:

| ID | Task | Duration | Start | Finish | Predecessors |
| --- | --- | --- | --- | --- | --- |
| 1 | Architectural Plans | 2w | 2018-05-07 | 2018-05-18 |  |
| 2 | Council approval | 1d | 2018-05-21 | 2018-05-21 | 1 |
| 3 | Site preparation | 3d | 2018-06-11 | 2018-06-13 | 2FS+14d |

Removed: 5 Slab down; 19 Lock up

Changed:

| ID | Task | Start | Finish | Duration | Total float | Predecessors | Other |
| --- | --- | --- | --- | --- | --- | --- | --- |
| 4 | Delivery of Materials | 2018-05-07 → 2018-06-11 (+35d) | 2018-06-15 → 2018-06-11 (-4d) | 6w → 1d | 0d → 38d | none → 3SS | was named Planning Stage; resources Architect → none |
| 5 | Lay Foundations | 2018-06-18 → 2018-06-14 (-4d) | 2018-06-20 → 2018-06-15 (-5d) | 3d → 2d |  | 4 → 3 | was named Footings; resources Concrete subcontractor → none |
| 6 | External Plumbing | 2018-06-21 → 2018-06-18 (-3d) | 2018-06-21 → 2018-06-18 (-3d) |  |  |  | resources Plumbing subcontractor → none |
| 7 | Pour foundation slab | 2018-06-22 → 2018-06-19 (-3d) | 2018-06-22 → 2018-06-19 (-3d) |  |  |  | resources Concrete subcontractor → none |
| 8 | Erect house frame | 2018-06-25 → 2018-06-20 (-5d) | 2018-06-29 → 2018-06-22 (-7d) | 5d → 3d |  | Slab down → 7 | resources Carpenters [300%]; Labourers [200%] → none |
| 9 | Roofing tiles | 2018-07-02 → 2018-06-25 (-7d) | 2018-07-04 → 2018-06-27 (-7d) |  |  |  | resources Roofing subcontractor → none |
| 10 | Brick Walls | 2018-07-05 → 2018-06-28 (-7d) | 2018-07-11 → 2018-07-04 (-7d) |  |  |  | resources Bricklayers [300%] → none |
| 11 | Fit Windows & Doors | 2018-07-12 → 2018-07-05 (-7d) | 2018-07-13 → 2018-07-06 (-7d) |  |  |  | resources Carpenters → none |
| 12 | Electrical Cables | 2018-07-16 → 2018-07-09 (-7d) | 2018-07-16 → 2018-07-09 (-7d) |  |  |  | resources Electrician → none |
| 13 | Internal Plumbing | 2018-07-16 → 2018-07-09 (-7d) | 2018-07-16 → 2018-07-09 (-7d) |  |  |  | resources Plumbing subcontractor → none |
| 14 | Plaster Walls | 2018-07-17 → 2018-07-10 (-7d) | 2018-07-23 → 2018-07-16 (-7d) |  |  |  | resources Plasterer → none |
| 15 | Internal Doors and Trim | 2018-07-24 → 2018-07-17 (-7d) | 2018-07-27 → 2018-07-20 (-7d) |  |  |  | resources Carpenters → none |
| 16 | Install Kitchen | 2018-07-30 → 2018-07-23 (-7d) | 2018-07-31 → 2018-07-24 (-7d) |  |  |  | resources Cabinetmaker [200%]; Plumber → none |
| 17 | Install Bathroom | 2018-07-30 → 2018-07-23 (-7d) | 2018-07-31 → 2018-07-24 (-7d) |  |  |  | resources Plumber; Tiler → none |
| 18 | Final Electrical Fittings | 2018-08-01 → 2018-07-25 (-7d) | 2018-08-02 → 2018-07-26 (-7d) |  |  |  | resources Electrician → none |
| 19 | Final Plumbing Fittings | 2018-08-01 → 2018-07-25 (-7d) | 2018-08-02 → 2018-07-26 (-7d) |  |  |  | resources Plumber → none |
| 20 | Paint | 2018-08-03 → 2018-07-27 (-7d) | 2018-08-09 → 2018-08-02 (-7d) |  |  |  | resources Painters [200%] → none |

## Version 5 (data date 2018-07-02, saved 2018-01-08, file PERT.mpp)

Last finish 2018-08-02 → 2018-08-09 (+7d).

Added:

| ID | Task | Duration | Start | Finish | Predecessors |
| --- | --- | --- | --- | --- | --- |
| 5 | Slab down | 0d | 2018-06-23 | 2018-06-23 | 4FS+24eh |
| 19 | Lock up | 0d | 2018-08-09 | 2018-08-09 | 18 |

Removed: 1 Architectural Plans; 2 Council approval; 3 Site preparation

Changed:

| ID | Task | Start | Finish | Duration | Total float | Predecessors | Other |
| --- | --- | --- | --- | --- | --- | --- | --- |
| 1 | Planning Stage | 2018-06-11 → 2018-05-07 (-35d) | 2018-06-11 → 2018-06-15 (+4d) | 1d → 6w | 38d → 0d | Site preparationSS → none | was named Delivery of Materials; resources none → Architect; baseline start none → 2011-04-04; baseline finish none → 2011-05-13 |
| 2 | Footings | 2018-06-14 → 2018-06-18 (+4d) | 2018-06-15 → 2018-06-20 (+5d) | 2d → 3d |  | Site preparation → 1 | was named Lay Foundations; resources none → Concrete subcontractor; baseline start none → 2011-05-16; baseline finish none → 2011-05-18 |
| 3 | External Plumbing | 2018-06-18 → 2018-06-21 (+3d) | 2018-06-18 → 2018-06-21 (+3d) |  |  |  | resources none → Plumbing subcontractor; baseline start none → 2011-05-19; baseline finish none → 2011-05-19 |
| 4 | Pour foundation slab | 2018-06-19 → 2018-06-22 (+3d) | 2018-06-19 → 2018-06-22 (+3d) |  |  |  | resources none → Concrete subcontractor; baseline start none → 2011-05-20; baseline finish none → 2011-05-20 |
| 6 | Erect house frame | 2018-06-20 → 2018-06-25 (+5d) | 2018-06-22 → 2018-06-29 (+7d) | 3d → 5d |  | 4 → 5 | resources none → Carpenters [300%]; Labourers [200%]; baseline start none → 2011-05-23; baseline finish none → 2011-05-27 |
| 7 | Roofing tiles | 2018-06-25 → 2018-07-02 (+7d) | 2018-06-27 → 2018-07-04 (+7d) |  |  |  | resources none → Roofing subcontractor; baseline start none → 2011-05-30; baseline finish none → 2011-06-01 |
| 8 | Brick Walls | 2018-06-28 → 2018-07-05 (+7d) | 2018-07-04 → 2018-07-11 (+7d) |  |  |  | resources none → Bricklayers [300%]; baseline start none → 2011-06-02; baseline finish none → 2011-06-08 |
| 9 | Fit Windows & Doors | 2018-07-05 → 2018-07-12 (+7d) | 2018-07-06 → 2018-07-13 (+7d) |  |  |  | resources none → Carpenters; baseline start none → 2011-06-09; baseline finish none → 2011-06-10 |
| 10 | Electrical Cables | 2018-07-09 → 2018-07-16 (+7d) | 2018-07-09 → 2018-07-16 (+7d) |  |  |  | resources none → Electrician; baseline start none → 2011-06-13; baseline finish none → 2011-06-13 |
| 11 | Internal Plumbing | 2018-07-09 → 2018-07-16 (+7d) | 2018-07-09 → 2018-07-16 (+7d) |  |  |  | resources none → Plumbing subcontractor; baseline start none → 2011-06-13; baseline finish none → 2011-06-13 |
| 12 | Plaster Walls | 2018-07-10 → 2018-07-17 (+7d) | 2018-07-16 → 2018-07-23 (+7d) |  |  |  | resources none → Plasterer; baseline start none → 2011-06-14; baseline finish none → 2011-06-20 |
| 13 | Internal Doors and Trim | 2018-07-17 → 2018-07-24 (+7d) | 2018-07-20 → 2018-07-27 (+7d) |  |  |  | resources none → Carpenters; baseline start none → 2011-06-21; baseline finish none → 2011-06-24 |
| 14 | Install Kitchen | 2018-07-23 → 2018-07-30 (+7d) | 2018-07-24 → 2018-07-31 (+7d) |  |  |  | resources none → Cabinetmaker [200%]; Plumber; baseline start none → 2011-06-27; baseline finish none → 2011-06-28 |
| 15 | Install Bathroom | 2018-07-23 → 2018-07-30 (+7d) | 2018-07-24 → 2018-07-31 (+7d) |  |  |  | resources none → Plumber; Tiler; baseline start none → 2011-06-27; baseline finish none → 2011-06-28 |
| 16 | Final Electrical Fittings | 2018-07-25 → 2018-08-01 (+7d) | 2018-07-26 → 2018-08-02 (+7d) |  |  |  | resources none → Electrician; baseline start none → 2011-06-29; baseline finish none → 2011-06-30 |
| 17 | Final Plumbing Fittings | 2018-07-25 → 2018-08-01 (+7d) | 2018-07-26 → 2018-08-02 (+7d) |  |  |  | resources none → Plumber; baseline start none → 2011-06-29; baseline finish none → 2011-06-30 |
| 18 | Paint | 2018-07-27 → 2018-08-03 (+7d) | 2018-08-02 → 2018-08-09 (+7d) |  |  |  | resources none → Painters [200%]; baseline start none → 2011-07-01; baseline finish none → 2011-07-07 |

## Version 6 (saved 2018-01-08, file Project A.mpp)

Last finish 2018-08-09 → 2018-08-02 (-7d).

Added:

| ID | Task | Duration | Start | Finish | Predecessors |
| --- | --- | --- | --- | --- | --- |
| 1 | Architectural Plans | 2w | 2018-05-07 | 2018-05-18 |  |
| 2 | Council approval | 1d | 2018-05-21 | 2018-05-21 | 1 |
| 3 | Site preparation | 3d | 2018-06-11 | 2018-06-13 | 2FS+14d |

Removed: 5 Slab down; 19 Lock up

Changed:

| ID | Task | Start | Finish | Duration | Total float | Predecessors | Other |
| --- | --- | --- | --- | --- | --- | --- | --- |
| 4 | Delivery of Materials | 2018-05-07 → 2018-06-11 (+35d) | 2018-06-15 → 2018-06-11 (-4d) | 6w → 1d | 0d → 38d | none → 3SS | was named Planning Stage; resources Architect → none; baseline start 2011-04-04 → none; baseline finish 2011-05-13 → none |
| 5 | Lay Foundations | 2018-06-18 → 2018-06-14 (-4d) | 2018-06-20 → 2018-06-15 (-5d) | 3d → 2d |  | 4 → 3 | was named Footings; resources Concrete subcontractor → none; baseline start 2011-05-16 → none; baseline finish 2011-05-18 → none |
| 6 | External Plumbing | 2018-06-21 → 2018-06-18 (-3d) | 2018-06-21 → 2018-06-18 (-3d) |  |  |  | resources Plumbing subcontractor → none; baseline start 2011-05-19 → none; baseline finish 2011-05-19 → none |
| 7 | Pour foundation slab | 2018-06-22 → 2018-06-19 (-3d) | 2018-06-22 → 2018-06-19 (-3d) |  |  |  | resources Concrete subcontractor → none; baseline start 2011-05-20 → none; baseline finish 2011-05-20 → none |
| 8 | Erect house frame | 2018-06-25 → 2018-06-20 (-5d) | 2018-06-29 → 2018-06-22 (-7d) | 5d → 3d |  | Slab down → 7 | resources Carpenters [300%]; Labourers [200%] → none; baseline start 2011-05-23 → none; baseline finish 2011-05-27 → none |
| 9 | Roofing tiles | 2018-07-02 → 2018-06-25 (-7d) | 2018-07-04 → 2018-06-27 (-7d) |  |  |  | resources Roofing subcontractor → none; baseline start 2011-05-30 → none; baseline finish 2011-06-01 → none |
| 10 | Brick Walls | 2018-07-05 → 2018-06-28 (-7d) | 2018-07-11 → 2018-07-04 (-7d) |  |  |  | resources Bricklayers [300%] → none; baseline start 2011-06-02 → none; baseline finish 2011-06-08 → none |
| 11 | Fit Windows & Doors | 2018-07-12 → 2018-07-05 (-7d) | 2018-07-13 → 2018-07-06 (-7d) |  |  |  | resources Carpenters → none; baseline start 2011-06-09 → none; baseline finish 2011-06-10 → none |
| 12 | Electrical Cables | 2018-07-16 → 2018-07-09 (-7d) | 2018-07-16 → 2018-07-09 (-7d) |  |  |  | resources Electrician → none; baseline start 2011-06-13 → none; baseline finish 2011-06-13 → none |
| 13 | Internal Plumbing | 2018-07-16 → 2018-07-09 (-7d) | 2018-07-16 → 2018-07-09 (-7d) |  |  |  | resources Plumbing subcontractor → none; baseline start 2011-06-13 → none; baseline finish 2011-06-13 → none |
| 14 | Plaster Walls | 2018-07-17 → 2018-07-10 (-7d) | 2018-07-23 → 2018-07-16 (-7d) |  |  |  | resources Plasterer → none; baseline start 2011-06-14 → none; baseline finish 2011-06-20 → none |
| 15 | Internal Doors and Trim | 2018-07-24 → 2018-07-17 (-7d) | 2018-07-27 → 2018-07-20 (-7d) |  |  |  | resources Carpenters → none; baseline start 2011-06-21 → none; baseline finish 2011-06-24 → none |
| 16 | Install Kitchen | 2018-07-30 → 2018-07-23 (-7d) | 2018-07-31 → 2018-07-24 (-7d) |  |  |  | resources Cabinetmaker [200%]; Plumber → none; baseline start 2011-06-27 → none; baseline finish 2011-06-28 → none |
| 17 | Install Bathroom | 2018-07-30 → 2018-07-23 (-7d) | 2018-07-31 → 2018-07-24 (-7d) |  |  |  | resources Plumber; Tiler → none; baseline start 2011-06-27 → none; baseline finish 2011-06-28 → none |
| 18 | Final Electrical Fittings | 2018-08-01 → 2018-07-25 (-7d) | 2018-08-02 → 2018-07-26 (-7d) |  |  |  | resources Electrician → none; baseline start 2011-06-29 → none; baseline finish 2011-06-30 → none |
| 19 | Final Plumbing Fittings | 2018-08-01 → 2018-07-25 (-7d) | 2018-08-02 → 2018-07-26 (-7d) |  |  |  | resources Plumber → none; baseline start 2011-06-29 → none; baseline finish 2011-06-30 → none |
| 20 | Paint | 2018-08-03 → 2018-07-27 (-7d) | 2018-08-09 → 2018-08-02 (-7d) |  |  |  | resources Painters [200%] → none; baseline start 2011-07-01 → none; baseline finish 2011-07-07 → none |

## Version 7 (saved 2018-01-08, file Project B.mpp)

Last finish 2018-08-02 → 2018-08-09 (+7d).

Changed:

| ID | Task | Start | Finish |
| --- | --- | --- | --- |
| 1 | Architectural Plans | 2018-05-07 → 2018-05-14 (+7d) | 2018-05-18 → 2018-05-25 (+7d) |
| 2 | Council approval | 2018-05-21 → 2018-05-28 (+7d) | 2018-05-21 → 2018-05-28 (+7d) |
| 3 | Site preparation | 2018-06-11 → 2018-06-18 (+7d) | 2018-06-13 → 2018-06-20 (+7d) |
| 4 | Delivery of Materials | 2018-06-11 → 2018-06-18 (+7d) | 2018-06-11 → 2018-06-18 (+7d) |
| 5 | Lay Foundations | 2018-06-14 → 2018-06-21 (+7d) | 2018-06-15 → 2018-06-22 (+7d) |
| 6 | External Plumbing | 2018-06-18 → 2018-06-25 (+7d) | 2018-06-18 → 2018-06-25 (+7d) |
| 7 | Pour foundation slab | 2018-06-19 → 2018-06-26 (+7d) | 2018-06-19 → 2018-06-26 (+7d) |
| 8 | Erect house frame | 2018-06-20 → 2018-06-27 (+7d) | 2018-06-22 → 2018-06-29 (+7d) |
| 9 | Roofing tiles | 2018-06-25 → 2018-07-02 (+7d) | 2018-06-27 → 2018-07-04 (+7d) |
| 10 | Brick Walls | 2018-06-28 → 2018-07-05 (+7d) | 2018-07-04 → 2018-07-11 (+7d) |
| 11 | Fit Windows & Doors | 2018-07-05 → 2018-07-12 (+7d) | 2018-07-06 → 2018-07-13 (+7d) |
| 12 | Electrical Cables | 2018-07-09 → 2018-07-16 (+7d) | 2018-07-09 → 2018-07-16 (+7d) |
| 13 | Internal Plumbing | 2018-07-09 → 2018-07-16 (+7d) | 2018-07-09 → 2018-07-16 (+7d) |
| 14 | Plaster Walls | 2018-07-10 → 2018-07-17 (+7d) | 2018-07-16 → 2018-07-23 (+7d) |
| 15 | Internal Doors and Trim | 2018-07-17 → 2018-07-24 (+7d) | 2018-07-20 → 2018-07-27 (+7d) |
| 16 | Install Kitchen | 2018-07-23 → 2018-07-30 (+7d) | 2018-07-24 → 2018-07-31 (+7d) |
| 17 | Install Bathroom | 2018-07-23 → 2018-07-30 (+7d) | 2018-07-24 → 2018-07-31 (+7d) |
| 18 | Final Electrical Fittings | 2018-07-25 → 2018-08-01 (+7d) | 2018-07-26 → 2018-08-02 (+7d) |
| 19 | Final Plumbing Fittings | 2018-07-25 → 2018-08-01 (+7d) | 2018-07-26 → 2018-08-02 (+7d) |
| 20 | Paint | 2018-07-27 → 2018-08-03 (+7d) | 2018-08-02 → 2018-08-09 (+7d) |

## Version 8 (saved 2018-01-08, file Project D.mpp)

Last finish 2018-08-09 → 2018-08-23 (+14d).

Changed:

| ID | Task | Start | Finish |
| --- | --- | --- | --- |
| 1 | Architectural Plans | 2018-05-14 → 2018-05-28 (+14d) | 2018-05-25 → 2018-06-08 (+14d) |
| 2 | Council approval | 2018-05-28 → 2018-06-11 (+14d) | 2018-05-28 → 2018-06-11 (+14d) |
| 3 | Site preparation | 2018-06-18 → 2018-07-02 (+14d) | 2018-06-20 → 2018-07-04 (+14d) |
| 4 | Delivery of Materials | 2018-06-18 → 2018-07-02 (+14d) | 2018-06-18 → 2018-07-02 (+14d) |
| 5 | Lay Foundations | 2018-06-21 → 2018-07-05 (+14d) | 2018-06-22 → 2018-07-06 (+14d) |
| 6 | External Plumbing | 2018-06-25 → 2018-07-09 (+14d) | 2018-06-25 → 2018-07-09 (+14d) |
| 7 | Pour foundation slab | 2018-06-26 → 2018-07-10 (+14d) | 2018-06-26 → 2018-07-10 (+14d) |
| 8 | Erect house frame | 2018-06-27 → 2018-07-11 (+14d) | 2018-06-29 → 2018-07-13 (+14d) |
| 9 | Roofing tiles | 2018-07-02 → 2018-07-16 (+14d) | 2018-07-04 → 2018-07-18 (+14d) |
| 10 | Brick Walls | 2018-07-05 → 2018-07-19 (+14d) | 2018-07-11 → 2018-07-25 (+14d) |
| 11 | Fit Windows & Doors | 2018-07-12 → 2018-07-26 (+14d) | 2018-07-13 → 2018-07-27 (+14d) |
| 12 | Electrical Cables | 2018-07-16 → 2018-07-30 (+14d) | 2018-07-16 → 2018-07-30 (+14d) |
| 13 | Internal Plumbing | 2018-07-16 → 2018-07-30 (+14d) | 2018-07-16 → 2018-07-30 (+14d) |
| 14 | Plaster Walls | 2018-07-17 → 2018-07-31 (+14d) | 2018-07-23 → 2018-08-06 (+14d) |
| 15 | Internal Doors and Trim | 2018-07-24 → 2018-08-07 (+14d) | 2018-07-27 → 2018-08-10 (+14d) |
| 16 | Install Kitchen | 2018-07-30 → 2018-08-13 (+14d) | 2018-07-31 → 2018-08-14 (+14d) |
| 17 | Install Bathroom | 2018-07-30 → 2018-08-13 (+14d) | 2018-07-31 → 2018-08-14 (+14d) |
| 18 | Final Electrical Fittings | 2018-08-01 → 2018-08-15 (+14d) | 2018-08-02 → 2018-08-16 (+14d) |
| 19 | Final Plumbing Fittings | 2018-08-01 → 2018-08-15 (+14d) | 2018-08-02 → 2018-08-16 (+14d) |
| 20 | Paint | 2018-08-03 → 2018-08-17 (+14d) | 2018-08-09 → 2018-08-23 (+14d) |

## Version 9 (saved 2018-01-08, file Project C.mpp)

Last finish 2018-08-23 → 2018-08-16 (-7d).

Changed:

| ID | Task | Start | Finish |
| --- | --- | --- | --- |
| 1 | Architectural Plans | 2018-05-28 → 2018-05-21 (-7d) | 2018-06-08 → 2018-06-01 (-7d) |
| 2 | Council approval | 2018-06-11 → 2018-06-04 (-7d) | 2018-06-11 → 2018-06-04 (-7d) |
| 3 | Site preparation | 2018-07-02 → 2018-06-25 (-7d) | 2018-07-04 → 2018-06-27 (-7d) |
| 4 | Delivery of Materials | 2018-07-02 → 2018-06-25 (-7d) | 2018-07-02 → 2018-06-25 (-7d) |
| 5 | Lay Foundations | 2018-07-05 → 2018-06-28 (-7d) | 2018-07-06 → 2018-06-29 (-7d) |
| 6 | External Plumbing | 2018-07-09 → 2018-07-02 (-7d) | 2018-07-09 → 2018-07-02 (-7d) |
| 7 | Pour foundation slab | 2018-07-10 → 2018-07-03 (-7d) | 2018-07-10 → 2018-07-03 (-7d) |
| 8 | Erect house frame | 2018-07-11 → 2018-07-04 (-7d) | 2018-07-13 → 2018-07-06 (-7d) |
| 9 | Roofing tiles | 2018-07-16 → 2018-07-09 (-7d) | 2018-07-18 → 2018-07-11 (-7d) |
| 10 | Brick Walls | 2018-07-19 → 2018-07-12 (-7d) | 2018-07-25 → 2018-07-18 (-7d) |
| 11 | Fit Windows & Doors | 2018-07-26 → 2018-07-19 (-7d) | 2018-07-27 → 2018-07-20 (-7d) |
| 12 | Electrical Cables | 2018-07-30 → 2018-07-23 (-7d) | 2018-07-30 → 2018-07-23 (-7d) |
| 13 | Internal Plumbing | 2018-07-30 → 2018-07-23 (-7d) | 2018-07-30 → 2018-07-23 (-7d) |
| 14 | Plaster Walls | 2018-07-31 → 2018-07-24 (-7d) | 2018-08-06 → 2018-07-30 (-7d) |
| 15 | Internal Doors and Trim | 2018-08-07 → 2018-07-31 (-7d) | 2018-08-10 → 2018-08-03 (-7d) |
| 16 | Install Kitchen | 2018-08-13 → 2018-08-06 (-7d) | 2018-08-14 → 2018-08-07 (-7d) |
| 17 | Install Bathroom | 2018-08-13 → 2018-08-06 (-7d) | 2018-08-14 → 2018-08-07 (-7d) |
| 18 | Final Electrical Fittings | 2018-08-15 → 2018-08-08 (-7d) | 2018-08-16 → 2018-08-09 (-7d) |
| 19 | Final Plumbing Fittings | 2018-08-15 → 2018-08-08 (-7d) | 2018-08-16 → 2018-08-09 (-7d) |
| 20 | Paint | 2018-08-17 → 2018-08-10 (-7d) | 2018-08-23 → 2018-08-16 (-7d) |
