# CKM Office Renovation

How a schedule from MS Project changed from version to version. A marks actual dates.

## Version 1 (saved 2018-01-08, file Advanced Tracking.mpp)

| ID | WBS | Task | Duration | Start | Finish | Predecessors | Total float | Constraint |
| --- | --- | --- | --- | --- | --- | --- | --- | --- |
| 1 | 1 | **Planning & Research** | 8.43d | 2018-05-07 09:00 | 2018-05-17 12:00 |  | 0d |  |
| 2 |  | Develop Requirements Documentation | 1d | 2018-05-07 09:00 | 2018-05-07 17:00 |  | 0d |  |
| 3 |  | Fit-Out Consultant Research | 0.5d | 2018-05-08 09:00 | 2018-05-08 12:30 | 2 | 0.5d |  |
| 4 |  | Telecommunications Consultant Research | 0.5d | 2018-05-08 12:30 | 2018-05-08 17:00 | 3 | 0.5d |  |
| 5 |  | IT Network Contractor Research | 0.5d | 2018-05-09 09:00 | 2018-05-09 12:30 | 4 | 0.5d |  |
| 6 |  | Building Contractors Research | 0.5d | 2018-05-09 12:30 | 2018-05-09 17:00 | 5 | 0.5d |  |
| 7 |  | Submit Requirements to Resources & Request Quotes | 2h | 2018-05-10 09:00 | 2018-05-10 11:00 | 6 | 0.5d |  |
| 8 |  | Quotes Received | 1h | 2018-05-17 11:00 | 2018-05-17 12:00 | 7FS+5d | 0.5d |  |
| 9 |  | Planning & Research Complete | 0d | 2018-05-17 12:00 | 2018-05-17 12:00 | 8 | 0.5d |  |
| 10 | 2 | **Management Approval** | 1.79d | 2018-05-17 12:00 | 2018-05-21 10:30 |  | 0.5d |  |
| 11 |  | Consolidate Quotes and develop proposal | 1.5d | 2018-05-17 12:00 | 2018-05-18 16:30 | 9 | 0.5d |  |
| 12 |  | Develop Project Plan & Durations | 1h | 2018-05-18 16:30 | 2018-05-21 09:30 | 11 | 0.5d |  |
| 13 |  | Submit Project Plan & Costs to Management | 1h | 2018-05-21 09:30 | 2018-05-21 10:30 | 12 | 0.5d |  |
| 14 |  | Management Approval Received | 0d | 2018-05-21 10:30 | 2018-05-21 10:30 | 13 | 0.5d |  |
| 15 | 3 | **Refit Office** | 14.79d | 2018-05-21 10:30 | 2018-06-08 17:00 |  | 0.5d |  |
| 16 |  | Appoint Resources | 2h | 2018-05-21 10:30 | 2018-05-21 12:30 | 14 | 0.5d |  |
| 17 |  | Staff Briefing | 1h | 2018-05-21 12:30 | 2018-05-21 14:30 | 16 | 0.5d |  |
| 18 | 3.3 | **Fit-Out Consultations** | 0.93d | 2018-05-21 14:30 | 2018-05-22 13:00 |  | 0.5d |  |
| 19 |  | Office Space / Structure Plan | 0.5d | 2018-05-21 14:30 | 2018-05-22 10:00 | 17 | 0.5d |  |
| 20 |  | Select & Order Carpet | 1h | 2018-05-22 10:00 | 2018-05-22 11:00 | 19 | 0.5d |  |
| 21 |  | Select & Order Paint | 1h | 2018-05-22 11:00 | 2018-05-22 12:00 | 20 | 0.5d |  |
| 22 |  | Select & Order Office Furniture | 1h | 2018-05-22 12:00 | 2018-05-22 13:00 | 21 | 0.5d |  |
| 23 | 3.4 | **Telecommuncations Consultations** | 0.64d | 2018-05-22 14:00 | 2018-05-23 10:30 |  | 0.5d |  |
| 24 |  | Design Telephone Access Points Map | 0.5d | 2018-05-22 14:00 | 2018-05-23 09:30 | 22 | 0.5d |  |
| 25 |  | Select & Order New PABX | 1h | 2018-05-23 09:30 | 2018-05-23 10:30 | 24 | 0.5d |  |
| 26 | 3.5 | **IT Networking Consultations** | 6.79d | 2018-05-23 10:30 | 2018-05-31 17:00 |  | 0.5d |  |
| 27 |  | Design Network Access Points Map | 0.5d | 2018-05-23 10:30 | 2018-05-23 15:00 | 22, 25 | 0.5d |  |
| 28 |  | Select & Order New PCs | 1h | 2018-05-23 15:00 | 2018-05-23 16:00 | 27 | 0.5d |  |
| 29 |  | New PCs Arrive | 1h | 2018-05-30 16:00 | 2018-05-30 17:00 | 28FS+5d | 0.5d |  |
| 30 |  | Configure SOE on PCs | 1d | 2018-05-31 09:00 | 2018-05-31 17:00 | 29 | 0.5d |  |
| 31 | 3.6 | **Restructure Office** | 13d | 2018-05-23 06:00 | 2018-06-08 17:00 |  | 0.5d |  |
| 32 |  | Erect New Walls | 7h | 2018-05-23 06:00 | 2018-05-25 07:00 | 22 | 1d |  |
| 33 |  | Gyprock, Plaster & Finish | 14h | 2018-05-25 07:00 | 2018-05-29 08:00 | 32 | 1d |  |
| 34 |  | Install Network Points | 5h | 2018-06-01 09:00 | 2018-06-01 15:00 | 33FS+1ed, 30 | 0.5d |  |
| 35 |  | Install Phone Connections | 0.5d | 2018-06-01 09:00 | 2018-06-01 12:30 | 34SS | 0.5d |  |
| 36 |  | Re-Paint | 1d | 2018-06-02 07:00 | 2018-06-02 15:00 | 35 | 0d |  |
| 37 |  | Carpet | 1d | 2018-06-04 06:00 | 2018-06-06 07:00 | 36FS+1ed | 0d |  |
| 38 |  | Install New Furniture | 1d | 2018-06-06 07:00 | 2018-06-08 08:00 | 37 | 0d |  |
| 39 |  | Install New PCs | 1d | 2018-06-08 09:00 | 2018-06-08 17:00 | 38 | 0.5d |  |
| 40 |  | Refit Office Complete | 0d | 2018-06-08 17:00 | 2018-06-08 17:00 | 39 | 0.5d |  |
| 41 | 4 | **Office Move** | 10d | 2018-05-31 09:00 | 2018-06-14 07:00 |  | 0d |  |
| 42 |  | Order packing boxes | 1h | 2018-05-31 09:00 | 2018-05-31 10:00 | 29 | 7.36d |  |
| 43 |  | Staff Pack | 0.5d | 2018-06-11 09:00 | 2018-06-11 12:30 | 40, 42 | 0.5d |  |
| 44 |  | Staff Move | 2d | 2018-06-11 12:30 | 2018-06-14 07:00 | 43 | 0d |  |
| 45 |  | Office Move Complete | 0d | 2018-06-14 07:00 | 2018-06-14 07:00 | 44 | 0d | finish no later than 2018-06-22 19:00 |

## Version 2 (saved 2018-01-08, file Customisations.mpp)

Last finish 2018-06-14 → 2018-06-21 (+7d). Complete tasks 0 → 33.

Changed:

| ID | Task | Start | Finish | Duration | Complete | Total float | Other |
| --- | --- | --- | --- | --- | --- | --- | --- |
| 1 | **Planning & Research** | 2018-05-07 09:00 A | 2018-05-17 12:00 A |  | 0% → 100% | 0d → none | baseline start 2011-04-04 09:00 → 2018-05-07 09:00; baseline finish 2011-04-14 12:00 → 2018-05-17 12:00 |
| 2 | Develop Requirements Documentation | 2018-05-07 09:00 A | 2018-05-07 17:00 A |  | 0% → 100% | 0d → none | baseline start 2011-04-04 09:00 → 2018-05-07 09:00; baseline finish 2011-04-04 17:00 → 2018-05-07 17:00 |
| 3 | Fit-Out Consultant Research | 2018-05-08 09:00 A | 2018-05-08 12:30 A |  | 0% → 100% | 0.5d → none | baseline start 2011-04-05 09:00 → 2018-05-08 09:00; baseline finish 2011-04-05 12:30 → 2018-05-08 12:30 |
| 4 | Telecommunications Consultant Research | 2018-05-08 12:30 A | 2018-05-08 17:00 A |  | 0% → 100% | 0.5d → none | baseline start 2011-04-05 12:30 → 2018-05-08 12:30; baseline finish 2011-04-05 17:00 → 2018-05-08 17:00 |
| 5 | IT Network Contractor Research | 2018-05-09 09:00 A | 2018-05-09 12:30 A |  | 0% → 100% | 0.5d → none | baseline start 2011-04-06 09:00 → 2018-05-09 09:00; baseline finish 2011-04-06 12:30 → 2018-05-09 12:30 |
| 6 | Building Contractors Research | 2018-05-09 12:30 A | 2018-05-09 17:00 A |  | 0% → 100% | 0.5d → none | baseline start 2011-04-06 12:30 → 2018-05-09 12:30; baseline finish 2011-04-06 17:00 → 2018-05-09 17:00 |
| 7 | Submit Requirements to Resources & Request Quotes | 2018-05-10 09:00 A | 2018-05-10 11:00 A |  | 0% → 100% | 0.5d → none | baseline start 2011-04-07 09:00 → 2018-05-10 09:00; baseline finish 2011-04-07 11:00 → 2018-05-10 11:00 |
| 8 | Quotes Received | 2018-05-17 11:00 A | 2018-05-17 12:00 A |  | 0% → 100% | 0.5d → none | baseline start 2011-04-14 11:00 → 2018-05-17 11:00; baseline finish 2011-04-14 12:00 → 2018-05-17 12:00 |
| 9 | Planning & Research Complete | 2018-05-17 12:00 A | 2018-05-17 12:00 A |  | 0% → 100% | 0.5d → none | baseline start 2011-04-14 12:00 → 2018-05-17 12:00; baseline finish 2011-04-14 12:00 → 2018-05-17 12:00 |
| 10 | **Management Approval** | 2018-05-17 12:00 A | 2018-05-21 10:30 A |  | 0% → 100% | 0.5d → none | baseline start 2011-04-14 12:00 → 2018-05-17 12:00; baseline finish 2011-04-15 15:00 → 2018-05-21 10:30 |
| 11 | Consolidate Quotes and develop proposal | 2018-05-17 12:00 A | 2018-05-18 16:30 A |  | 0% → 100% | 0.5d → none | baseline start 2011-04-14 12:00 → 2018-05-17 12:00; baseline finish 2011-04-15 12:00 → 2018-05-18 16:30 |
| 12 | Develop Project Plan & Durations | 2018-05-18 16:30 A | 2018-05-21 09:30 A |  | 0% → 100% | 0.5d → none | baseline start 2011-04-15 12:00 → 2018-05-18 16:30; baseline finish 2011-04-15 13:00 → 2018-05-21 09:30 |
| 13 | Submit Project Plan & Costs to Management | 2018-05-21 09:30 A | 2018-05-21 10:30 A |  | 0% → 100% | 0.5d → none | baseline start 2011-04-15 14:00 → 2018-05-21 09:30; baseline finish 2011-04-15 15:00 → 2018-05-21 10:30 |
| 14 | Management Approval Received | 2018-05-21 10:30 A | 2018-05-21 10:30 A |  | 0% → 100% | 0.5d → none | baseline start 2011-04-15 15:00 → 2018-05-21 10:30; baseline finish 2011-04-15 15:00 → 2018-05-21 10:30 |
| 15 | **Refit Office** | 2018-05-21 10:30 A | 2018-06-08 17:00 → 2018-06-18 09:00 A (+10d) | 14.79d → 19.79d | 0% → 100% | 0.5d → none | baseline start 2011-04-15 15:00 → 2018-05-21 10:30; baseline finish 2011-05-11 17:00 → 2018-06-18 09:00 |
| 16 | Appoint Resources | 2018-05-21 10:30 A | 2018-05-21 12:30 A |  | 0% → 100% | 0.5d → none | baseline start 2011-04-15 15:00 → 2018-05-21 10:30; baseline finish 2011-04-15 17:00 → 2018-05-21 12:30 |
| 17 | Staff Briefing | 2018-05-21 12:30 A | 2018-05-21 14:30 A |  | 0% → 100% | 0.5d → none | baseline start 2011-04-18 09:00 → 2018-05-21 12:30; baseline finish 2011-04-18 10:00 → 2018-05-21 14:30 |
| 18 | **Fit-Out Consultations** | 2018-05-21 14:30 A | 2018-05-22 13:00 A |  | 0% → 100% | 0.5d → none | baseline start 2011-04-18 10:00 → 2018-05-21 14:30; baseline finish 2011-04-19 09:30 → 2018-05-22 13:00 |
| 19 | Office Space / Structure Plan | 2018-05-21 14:30 A | 2018-05-22 10:00 A |  | 0% → 100% | 0.5d → none | baseline start 2011-04-18 10:00 → 2018-05-21 14:30; baseline finish 2011-04-18 14:30 → 2018-05-22 10:00 |
| 20 | Select & Order Carpet | 2018-05-22 10:00 A | 2018-05-22 11:00 A |  | 0% → 100% | 0.5d → none | baseline start 2011-04-18 14:30 → 2018-05-22 10:00; baseline finish 2011-04-18 15:30 → 2018-05-22 11:00 |
| 21 | Select & Order Paint | 2018-05-22 11:00 A | 2018-05-22 12:00 A |  | 0% → 100% | 0.5d → none | baseline start 2011-04-18 15:30 → 2018-05-22 11:00; baseline finish 2011-04-18 16:30 → 2018-05-22 12:00 |
| 22 | Select & Order Office Furniture | 2018-05-22 12:00 A | 2018-05-22 13:00 A |  | 0% → 100% | 0.5d → none | baseline start 2011-04-18 16:30 → 2018-05-22 12:00; baseline finish 2011-04-19 09:30 → 2018-05-22 13:00 |
| 23 | **Telecommuncations Consultations** | 2018-05-22 14:00 A | 2018-05-23 10:30 A |  | 0% → 100% | 0.5d → none | baseline start 2011-04-19 09:30 → 2018-05-22 14:00; baseline finish 2011-04-19 15:00 → 2018-05-23 10:30 |
| 24 | Design Telephone Access Points Map | 2018-05-22 14:00 A | 2018-05-23 09:30 A |  | 0% → 100% | 0.5d → none | baseline start 2011-04-19 09:30 → 2018-05-22 14:00; baseline finish 2011-04-19 13:00 → 2018-05-23 09:30 |
| 25 | Select & Order New PABX | 2018-05-23 09:30 A | 2018-05-23 10:30 A |  | 0% → 100% | 0.5d → none | baseline start 2011-04-19 14:00 → 2018-05-23 09:30; baseline finish 2011-04-19 15:00 → 2018-05-23 10:30 |
| 26 | **IT Networking Consultations** | 2018-05-23 10:30 A | 2018-05-31 17:00 → 2018-06-05 17:00 A (+5d) | 6.79d → 9.79d | 0% → 100% | 0.5d → none | baseline start 2011-04-19 15:00 → 2018-05-23 10:30; baseline finish 2011-05-03 12:30 → 2018-06-05 17:00 |
| 27 | Design Network Access Points Map | 2018-05-23 10:30 A | 2018-05-23 15:00 A |  | 0% → 100% | 0.5d → none | baseline start 2011-04-19 15:00 → 2018-05-23 10:30; baseline finish 2011-04-20 10:30 → 2018-05-23 15:00 |
| 28 | Select & Order New PCs | 2018-05-23 15:00 A | 2018-05-23 16:00 A |  | 0% → 100% | 0.5d → none | baseline start 2011-04-20 10:30 → 2018-05-23 15:00; baseline finish 2011-04-20 11:30 → 2018-05-23 16:00 |
| 29 | New PCs Arrive | 2018-05-30 16:00 → 2018-06-01 16:00 A (+2d) | 2018-05-30 17:00 → 2018-06-01 17:00 A (+2d) |  | 0% → 100% | 0.5d → none | baseline start 2011-04-29 11:30 → 2018-06-01 16:00; baseline finish 2011-04-29 12:30 → 2018-06-01 17:00 |
| 30 | Configure SOE on PCs | 2018-05-31 09:00 → 2018-06-05 09:00 A (+5d) | 2018-05-31 17:00 → 2018-06-05 17:00 A (+5d) |  | 0% → 100% | 0.5d → none | baseline start 2011-04-29 12:30 → 2018-06-05 09:00; baseline finish 2011-05-03 12:30 → 2018-06-05 17:00 |
| 31 | **Restructure Office** | 2018-05-23 06:00 → 2018-05-23 09:00 A | 2018-06-08 17:00 → 2018-06-18 09:00 A (+10d) | 13d → 18d | 0% → 100% | 0.5d → none | baseline start 2011-04-20 06:00 → 2018-05-23 09:00; baseline finish 2011-05-11 17:00 → 2018-06-18 09:00 |
| 32 | Erect New Walls | 2018-05-23 06:00 → 2018-05-23 09:00 A | 2018-05-25 07:00 → 2018-05-26 08:00 A (+1d) |  | 0% → 100% | 1d → none | baseline start 2011-04-20 06:00 → 2018-05-23 09:00; baseline finish 2011-04-26 07:00 → 2018-05-26 08:00 |
| 33 | Gyprock, Plaster & Finish | 2018-05-25 07:00 → 2018-05-29 09:00 A (+4d) | 2018-05-29 08:00 → 2018-06-02 13:00 A (+4d) |  | 0% → 100% | 1d → none | baseline start 2011-04-26 07:00 → 2018-05-29 09:00; baseline finish 2011-04-30 10:00 → 2018-06-02 13:00 |
| 34 | Install Network Points | 2018-06-01 09:00 → 2018-06-06 09:00 A (+5d) | 2018-06-01 15:00 → 2018-06-06 15:00 A (+5d) |  | 0% → 100% | 0.5d → none | baseline start 2011-05-03 12:30 → 2018-06-06 09:00; baseline finish 2011-05-04 10:30 → 2018-06-06 15:00 |
| 35 | Install Phone Connections | 2018-06-01 09:00 → 2018-06-06 09:00 A (+5d) | 2018-06-01 12:30 → 2018-06-06 12:30 A (+5d) |  | 0% → 100% | 0.5d → none | baseline start 2011-05-03 12:30 → 2018-06-06 09:00; baseline finish 2011-05-03 17:00 → 2018-06-06 12:30 |
| 36 | Re-Paint | 2018-06-02 07:00 → 2018-06-07 09:00 A (+5d) | 2018-06-02 15:00 → 2018-06-09 11:00 A (+7d) |  | 0% → 100% | 0d → none | baseline start 2011-05-04 06:00 → 2018-06-07 09:00; baseline finish 2011-05-06 07:00 → 2018-06-09 11:00 |
| 37 | Carpet | 2018-06-04 06:00 → 2018-06-11 09:00 A (+7d) | 2018-06-06 07:00 → 2018-06-14 07:00 A (+8d) |  | 0% → 100% | 0d → none | baseline start 2011-05-07 07:00 → 2018-06-11 09:00; baseline finish 2011-05-07 15:00 → 2018-06-14 07:00 |
| 38 | Install New Furniture | 2018-06-06 07:00 → 2018-06-13 09:00 A (+7d) | 2018-06-08 08:00 → 2018-06-16 08:00 A (+8d) |  | 0% → 100% | 0d → none | baseline start 2011-05-09 06:00 → 2018-06-13 09:00; baseline finish 2011-05-11 07:00 → 2018-06-16 08:00 |
| 39 | Install New PCs | 2018-06-08 09:00 → 2018-06-15 09:00 A (+7d) | 2018-06-08 17:00 → 2018-06-15 17:00 A (+7d) |  | 0% → 100% | 0.5d → none | baseline start 2011-05-11 09:00 → 2018-06-15 09:00; baseline finish 2011-05-11 17:00 → 2018-06-15 17:00 |
| 40 | Refit Office Complete | 2018-06-08 17:00 → 2018-06-18 09:00 A (+10d) | 2018-06-08 17:00 → 2018-06-18 09:00 A (+10d) |  | 0% → 100% | 0.5d → none | baseline start 2011-05-11 17:00 → 2018-06-18 09:00; baseline finish 2011-05-11 17:00 → 2018-06-18 09:00 |
| 41 | **Office Move** | 2018-05-31 09:00 → 2018-06-04 09:00 (+4d) | 2018-06-14 07:00 → 2018-06-21 07:00 (+7d) | 10d → 13d |  |  | baseline start 2011-04-29 12:30 → 2018-06-04 09:00; baseline finish 2011-05-16 17:00 → 2018-06-21 07:00 |
| 42 | Order packing boxes | 2018-05-31 09:00 → 2018-06-04 09:00 (+4d) | 2018-05-31 10:00 → 2018-06-04 10:00 (+4d) |  |  | 7.36d → 10.36d | baseline start 2011-04-29 12:30 → 2018-06-04 09:00; baseline finish 2011-04-29 14:30 → 2018-06-04 10:00 |
| 43 | Staff Pack | 2018-06-11 09:00 → 2018-06-18 09:00 (+7d) | 2018-06-11 12:30 → 2018-06-18 12:30 (+7d) |  |  |  | baseline start 2011-05-12 09:00 → 2018-06-18 09:00; baseline finish 2011-05-12 12:30 → 2018-06-18 12:30 |
| 44 | Staff Move | 2018-06-11 12:30 → 2018-06-18 12:30 (+7d) | 2018-06-14 07:00 → 2018-06-21 07:00 (+7d) |  |  |  | baseline start 2011-05-12 12:30 → 2018-06-18 12:30; baseline finish 2011-05-14 11:00 → 2018-06-21 07:00 |
| 45 | Office Move Complete | 2018-06-14 07:00 → 2018-06-21 07:00 (+7d) | 2018-06-14 07:00 → 2018-06-21 07:00 (+7d) |  |  |  | constraint finish no later than 2018-06-22 19:00 → none; baseline start 2011-05-16 17:00 → 2018-06-21 07:00; baseline finish 2011-05-16 17:00 → 2018-06-21 07:00 |

## Version 3 (saved 2018-01-08, file Fields.mpp)

Last finish stays 2018-06-21.

Changed:

| ID | Task | Other |
| --- | --- | --- |
| 45 | Office Move Complete | constraint none → finish no later than 2018-06-22 19:00 |

## Version 4 (saved 2018-01-08, file Grouping.mpp)

Last finish 2018-06-21 → 2018-06-25 (+4d).

Changed:

| ID | Task | Start | Finish | Duration | Other |
| --- | --- | --- | --- | --- | --- |
| 41 | **Office Move** |  | 2018-06-21 07:00 → 2018-06-25 09:00 (+4d) | 13d → 15d | baseline finish 2018-06-21 07:00 → 2018-06-25 09:00 |
| 45 | Office Move Complete | 2018-06-21 07:00 → 2018-06-25 09:00 (+4d) | 2018-06-21 07:00 → 2018-06-25 09:00 (+4d) |  | constraint finish no later than 2018-06-22 19:00 → finish no earlier than 2018-06-25 09:00; baseline start 2018-06-21 07:00 → 2018-06-25 09:00; baseline finish 2018-06-21 07:00 → 2018-06-25 09:00 |

## Version 5 (data date 2017-12-12, saved 2018-01-08, file Formulas.mpp)

Last finish 2018-06-25 → 2018-06-14 (-11d). Complete tasks 33 → 0.

Changed:

| ID | Task | Start | Finish | Duration | Complete | Total float | Other |
| --- | --- | --- | --- | --- | --- | --- | --- |
| 1 | **Planning & Research** | 2018-05-07 09:00 A → 2018-05-07 09:00 | 2018-05-17 12:00 A → 2018-05-17 12:00 |  | 100% → 0% | none → 0d |  |
| 2 | Develop Requirements Documentation | 2018-05-07 09:00 A → 2018-05-07 09:00 | 2018-05-07 17:00 A → 2018-05-07 17:00 |  | 100% → 0% | none → 0d |  |
| 3 | Fit-Out Consultant Research | 2018-05-08 09:00 A → 2018-05-08 09:00 | 2018-05-08 12:30 A → 2018-05-08 12:30 |  | 100% → 0% | none → 0.5d |  |
| 4 | Telecommunications Consultant Research | 2018-05-08 12:30 A → 2018-05-08 12:30 | 2018-05-08 17:00 A → 2018-05-08 17:00 |  | 100% → 0% | none → 0.5d |  |
| 5 | IT Network Contractor Research | 2018-05-09 09:00 A → 2018-05-09 09:00 | 2018-05-09 12:30 A → 2018-05-09 12:30 |  | 100% → 0% | none → 0.5d |  |
| 6 | Building Contractors Research | 2018-05-09 12:30 A → 2018-05-09 12:30 | 2018-05-09 17:00 A → 2018-05-09 17:00 |  | 100% → 0% | none → 0.5d |  |
| 7 | Submit Requirements to Resources & Request Quotes | 2018-05-10 09:00 A → 2018-05-10 09:00 | 2018-05-10 11:00 A → 2018-05-10 11:00 |  | 100% → 0% | none → 0.5d |  |
| 8 | Quotes Received | 2018-05-17 11:00 A → 2018-05-17 11:00 | 2018-05-17 12:00 A → 2018-05-17 12:00 |  | 100% → 0% | none → 0.5d |  |
| 9 | Planning & Research Complete | 2018-05-17 12:00 A → 2018-05-17 12:00 | 2018-05-17 12:00 A → 2018-05-17 12:00 |  | 100% → 0% | none → 0.5d |  |
| 10 | **Management Approval** | 2018-05-17 12:00 A → 2018-05-17 12:00 | 2018-05-21 10:30 A → 2018-05-21 10:30 |  | 100% → 0% | none → 0.5d |  |
| 11 | Consolidate Quotes and develop proposal | 2018-05-17 12:00 A → 2018-05-17 12:00 | 2018-05-18 16:30 A → 2018-05-18 16:30 |  | 100% → 0% | none → 0.5d |  |
| 12 | Develop Project Plan & Durations | 2018-05-18 16:30 A → 2018-05-18 16:30 | 2018-05-21 09:30 A → 2018-05-21 09:30 |  | 100% → 0% | none → 0.5d |  |
| 13 | Submit Project Plan & Costs to Management | 2018-05-21 09:30 A → 2018-05-21 09:30 | 2018-05-21 10:30 A → 2018-05-21 10:30 |  | 100% → 0% | none → 0.5d |  |
| 14 | Management Approval Received | 2018-05-21 10:30 A → 2018-05-21 10:30 | 2018-05-21 10:30 A → 2018-05-21 10:30 |  | 100% → 0% | none → 0.5d |  |
| 15 | **Refit Office** | 2018-05-21 10:30 A → 2018-05-21 10:30 | 2018-06-18 09:00 A → 2018-06-08 17:00 (-10d) | 19.79d → 14.79d | 100% → 0% | none → 0.5d | baseline finish 2018-06-18 09:00 → 2018-06-08 17:00 |
| 16 | Appoint Resources | 2018-05-21 10:30 A → 2018-05-21 10:30 | 2018-05-21 12:30 A → 2018-05-21 12:30 |  | 100% → 0% | none → 0.5d |  |
| 17 | Staff Briefing | 2018-05-21 12:30 A → 2018-05-21 12:30 | 2018-05-21 14:30 A → 2018-05-21 14:30 |  | 100% → 0% | none → 0.5d |  |
| 18 | **Fit-Out Consultations** | 2018-05-21 14:30 A → 2018-05-21 14:30 | 2018-05-22 13:00 A → 2018-05-22 13:00 |  | 100% → 0% | none → 0.5d |  |
| 19 | Office Space / Structure Plan | 2018-05-21 14:30 A → 2018-05-21 14:30 | 2018-05-22 10:00 A → 2018-05-22 10:00 |  | 100% → 0% | none → 0.5d |  |
| 20 | Select & Order Carpet | 2018-05-22 10:00 A → 2018-05-22 10:00 | 2018-05-22 11:00 A → 2018-05-22 11:00 |  | 100% → 0% | none → 0.5d |  |
| 21 | Select & Order Paint | 2018-05-22 11:00 A → 2018-05-22 11:00 | 2018-05-22 12:00 A → 2018-05-22 12:00 |  | 100% → 0% | none → 0.5d |  |
| 22 | Select & Order Office Furniture | 2018-05-22 12:00 A → 2018-05-22 12:00 | 2018-05-22 13:00 A → 2018-05-22 13:00 |  | 100% → 0% | none → 0.5d |  |
| 23 | **Telecommuncations Consultations** | 2018-05-22 14:00 A → 2018-05-22 14:00 | 2018-05-23 10:30 A → 2018-05-23 10:30 |  | 100% → 0% | none → 0.5d |  |
| 24 | Design Telephone Access Points Map | 2018-05-22 14:00 A → 2018-05-22 14:00 | 2018-05-23 09:30 A → 2018-05-23 09:30 |  | 100% → 0% | none → 0.5d |  |
| 25 | Select & Order New PABX | 2018-05-23 09:30 A → 2018-05-23 09:30 | 2018-05-23 10:30 A → 2018-05-23 10:30 |  | 100% → 0% | none → 0.5d |  |
| 26 | **IT Networking Consultations** | 2018-05-23 10:30 A → 2018-05-23 10:30 | 2018-06-05 17:00 A → 2018-05-31 17:00 (-5d) | 9.79d → 6.79d | 100% → 0% | none → 0.5d | baseline finish 2018-06-05 17:00 → 2018-05-31 17:00 |
| 27 | Design Network Access Points Map | 2018-05-23 10:30 A → 2018-05-23 10:30 | 2018-05-23 15:00 A → 2018-05-23 15:00 |  | 100% → 0% | none → 0.5d |  |
| 28 | Select & Order New PCs | 2018-05-23 15:00 A → 2018-05-23 15:00 | 2018-05-23 16:00 A → 2018-05-23 16:00 |  | 100% → 0% | none → 0.5d |  |
| 29 | New PCs Arrive | 2018-06-01 16:00 A → 2018-05-30 16:00 (-2d) | 2018-06-01 17:00 A → 2018-05-30 17:00 (-2d) |  | 100% → 0% | none → 0.5d | baseline start 2018-06-01 16:00 → 2018-05-30 16:00; baseline finish 2018-06-01 17:00 → 2018-05-30 17:00 |
| 30 | Configure SOE on PCs | 2018-06-05 09:00 A → 2018-05-31 09:00 (-5d) | 2018-06-05 17:00 A → 2018-05-31 17:00 (-5d) |  | 100% → 0% | none → 0.5d | baseline start 2018-06-05 09:00 → 2018-05-31 09:00; baseline finish 2018-06-05 17:00 → 2018-05-31 17:00 |
| 31 | **Restructure Office** | 2018-05-23 09:00 A → 2018-05-23 06:00 | 2018-06-18 09:00 A → 2018-06-08 17:00 (-10d) | 18d → 13d | 100% → 0% | none → 0.5d | baseline start 2018-05-23 09:00 → 2018-05-23 06:00; baseline finish 2018-06-18 09:00 → 2018-06-08 17:00 |
| 32 | Erect New Walls | 2018-05-23 09:00 A → 2018-05-23 06:00 | 2018-05-26 08:00 A → 2018-05-25 07:00 (-1d) |  | 100% → 0% | none → 1d | baseline start 2018-05-23 09:00 → 2018-05-23 06:00; baseline finish 2018-05-26 08:00 → 2018-05-25 07:00 |
| 33 | Gyprock, Plaster & Finish | 2018-05-29 09:00 A → 2018-05-25 07:00 (-4d) | 2018-06-02 13:00 A → 2018-05-29 08:00 (-4d) |  | 100% → 0% | none → 1d | baseline start 2018-05-29 09:00 → 2018-05-25 07:00; baseline finish 2018-06-02 13:00 → 2018-05-29 08:00 |
| 34 | Install Network Points | 2018-06-06 09:00 A → 2018-06-01 09:00 (-5d) | 2018-06-06 15:00 A → 2018-06-01 15:00 (-5d) |  | 100% → 0% | none → 0.5d | baseline start 2018-06-06 09:00 → 2018-06-01 09:00; baseline finish 2018-06-06 15:00 → 2018-06-01 15:00 |
| 35 | Install Phone Connections | 2018-06-06 09:00 A → 2018-06-01 09:00 (-5d) | 2018-06-06 12:30 A → 2018-06-01 12:30 (-5d) |  | 100% → 0% | none → 0.5d | baseline start 2018-06-06 09:00 → 2018-06-01 09:00; baseline finish 2018-06-06 12:30 → 2018-06-01 12:30 |
| 36 | Re-Paint | 2018-06-07 09:00 A → 2018-06-02 07:00 (-5d) | 2018-06-09 11:00 A → 2018-06-02 15:00 (-7d) |  | 100% → 0% | none → 0d | baseline start 2018-06-07 09:00 → 2018-06-02 07:00; baseline finish 2018-06-09 11:00 → 2018-06-02 15:00 |
| 37 | Carpet | 2018-06-11 09:00 A → 2018-06-04 06:00 (-7d) | 2018-06-14 07:00 A → 2018-06-06 07:00 (-8d) |  | 100% → 0% | none → 0d | baseline start 2018-06-11 09:00 → 2018-06-04 06:00; baseline finish 2018-06-14 07:00 → 2018-06-06 07:00 |
| 38 | Install New Furniture | 2018-06-13 09:00 A → 2018-06-06 07:00 (-7d) | 2018-06-16 08:00 A → 2018-06-08 08:00 (-8d) |  | 100% → 0% | none → 0d | baseline start 2018-06-13 09:00 → 2018-06-06 07:00; baseline finish 2018-06-16 08:00 → 2018-06-08 08:00 |
| 39 | Install New PCs | 2018-06-15 09:00 A → 2018-06-08 09:00 (-7d) | 2018-06-15 17:00 A → 2018-06-08 17:00 (-7d) |  | 100% → 0% | none → 0.5d | baseline start 2018-06-15 09:00 → 2018-06-08 09:00; baseline finish 2018-06-15 17:00 → 2018-06-08 17:00 |
| 40 | Refit Office Complete | 2018-06-18 09:00 A → 2018-06-08 17:00 (-10d) | 2018-06-18 09:00 A → 2018-06-08 17:00 (-10d) |  | 100% → 0% | none → 0.5d | baseline start 2018-06-18 09:00 → 2018-06-08 17:00; baseline finish 2018-06-18 09:00 → 2018-06-08 17:00 |
| 41 | **Office Move** | 2018-06-04 09:00 → 2018-05-31 09:00 (-4d) | 2018-06-25 09:00 → 2018-06-14 07:00 (-11d) | 15d → 10d |  |  | baseline start 2018-06-04 09:00 → 2018-05-31 09:00; baseline finish 2018-06-25 09:00 → 2018-06-14 07:00 |
| 42 | Order packing boxes | 2018-06-04 09:00 → 2018-05-31 09:00 (-4d) | 2018-06-04 10:00 → 2018-05-31 10:00 (-4d) |  |  | 13.36d → 7.36d | baseline start 2018-06-04 09:00 → 2018-05-31 09:00; baseline finish 2018-06-04 10:00 → 2018-05-31 10:00 |
| 43 | Staff Pack | 2018-06-18 09:00 → 2018-06-11 09:00 (-7d) | 2018-06-18 12:30 → 2018-06-11 12:30 (-7d) |  |  | 3.5d → 0.5d | baseline start 2018-06-18 09:00 → 2018-06-11 09:00; baseline finish 2018-06-18 12:30 → 2018-06-11 12:30 |
| 44 | Staff Move | 2018-06-18 12:30 → 2018-06-11 12:30 (-7d) | 2018-06-21 07:00 → 2018-06-14 07:00 (-7d) |  |  | 2d → 0d | baseline start 2018-06-18 12:30 → 2018-06-11 12:30; baseline finish 2018-06-21 07:00 → 2018-06-14 07:00 |
| 45 | Office Move Complete | 2018-06-25 09:00 → 2018-06-14 07:00 (-11d) | 2018-06-25 09:00 → 2018-06-14 07:00 (-11d) |  |  |  | constraint finish no earlier than 2018-06-25 09:00 → finish no later than 2018-06-22 19:00; baseline start 2018-06-25 09:00 → 2018-06-14 07:00; baseline finish 2018-06-25 09:00 → 2018-06-14 07:00 |

## Version 6 (saved 2018-01-08, file Importing.mpp)

Last finish 2018-06-14 → 2018-06-21 (+7d). Complete tasks 0 → 33.

Changed:

| ID | Task | Start | Finish | Duration | Complete | Total float | Other |
| --- | --- | --- | --- | --- | --- | --- | --- |
| 1 | **Planning & Research** | 2018-05-07 09:00 A | 2018-05-17 12:00 A |  | 0% → 100% | 0d → none |  |
| 2 | Develop Requirements Documentation | 2018-05-07 09:00 A | 2018-05-07 17:00 A |  | 0% → 100% | 0d → none |  |
| 3 | Fit-Out Consultant Research | 2018-05-08 09:00 A | 2018-05-08 12:30 A |  | 0% → 100% | 0.5d → none |  |
| 4 | Telecommunications Consultant Research | 2018-05-08 12:30 A | 2018-05-08 17:00 A |  | 0% → 100% | 0.5d → none |  |
| 5 | IT Network Contractor Research | 2018-05-09 09:00 A | 2018-05-09 12:30 A |  | 0% → 100% | 0.5d → none |  |
| 6 | Building Contractors Research | 2018-05-09 12:30 A | 2018-05-09 17:00 A |  | 0% → 100% | 0.5d → none |  |
| 7 | Submit Requirements to Resources & Request Quotes | 2018-05-10 09:00 A | 2018-05-10 11:00 A |  | 0% → 100% | 0.5d → none |  |
| 8 | Quotes Received | 2018-05-17 11:00 A | 2018-05-17 12:00 A |  | 0% → 100% | 0.5d → none |  |
| 9 | Planning & Research Complete | 2018-05-17 12:00 A | 2018-05-17 12:00 A |  | 0% → 100% | 0.5d → none |  |
| 10 | **Management Approval** | 2018-05-17 12:00 A | 2018-05-21 10:30 A |  | 0% → 100% | 0.5d → none |  |
| 11 | Consolidate Quotes and develop proposal | 2018-05-17 12:00 A | 2018-05-18 16:30 A |  | 0% → 100% | 0.5d → none |  |
| 12 | Develop Project Plan & Durations | 2018-05-18 16:30 A | 2018-05-21 09:30 A |  | 0% → 100% | 0.5d → none |  |
| 13 | Submit Project Plan & Costs to Management | 2018-05-21 09:30 A | 2018-05-21 10:30 A |  | 0% → 100% | 0.5d → none |  |
| 14 | Management Approval Received | 2018-05-21 10:30 A | 2018-05-21 10:30 A |  | 0% → 100% | 0.5d → none |  |
| 15 | **Refit Office** | 2018-05-21 10:30 A | 2018-06-08 17:00 → 2018-06-18 09:00 A (+10d) | 14.79d → 19.79d | 0% → 100% | 0.5d → none | baseline finish 2018-06-08 17:00 → 2018-06-18 09:00 |
| 16 | Appoint Resources | 2018-05-21 10:30 A | 2018-05-21 12:30 A |  | 0% → 100% | 0.5d → none |  |
| 17 | Staff Briefing | 2018-05-21 12:30 A | 2018-05-21 14:30 A |  | 0% → 100% | 0.5d → none |  |
| 18 | **Fit-Out Consultations** | 2018-05-21 14:30 A | 2018-05-22 13:00 A |  | 0% → 100% | 0.5d → none |  |
| 19 | Office Space / Structure Plan | 2018-05-21 14:30 A | 2018-05-22 10:00 A |  | 0% → 100% | 0.5d → none |  |
| 20 | Select & Order Carpet | 2018-05-22 10:00 A | 2018-05-22 11:00 A |  | 0% → 100% | 0.5d → none |  |
| 21 | Select & Order Paint | 2018-05-22 11:00 A | 2018-05-22 12:00 A |  | 0% → 100% | 0.5d → none |  |
| 22 | Select & Order Office Furniture | 2018-05-22 12:00 A | 2018-05-22 13:00 A |  | 0% → 100% | 0.5d → none |  |
| 23 | **Telecommuncations Consultations** | 2018-05-22 14:00 A | 2018-05-23 10:30 A |  | 0% → 100% | 0.5d → none |  |
| 24 | Design Telephone Access Points Map | 2018-05-22 14:00 A | 2018-05-23 09:30 A |  | 0% → 100% | 0.5d → none |  |
| 25 | Select & Order New PABX | 2018-05-23 09:30 A | 2018-05-23 10:30 A |  | 0% → 100% | 0.5d → none |  |
| 26 | **IT Networking Consultations** | 2018-05-23 10:30 A | 2018-05-31 17:00 → 2018-06-05 17:00 A (+5d) | 6.79d → 9.79d | 0% → 100% | 0.5d → none | baseline finish 2018-05-31 17:00 → 2018-06-05 17:00 |
| 27 | Design Network Access Points Map | 2018-05-23 10:30 A | 2018-05-23 15:00 A |  | 0% → 100% | 0.5d → none |  |
| 28 | Select & Order New PCs | 2018-05-23 15:00 A | 2018-05-23 16:00 A |  | 0% → 100% | 0.5d → none |  |
| 29 | New PCs Arrive | 2018-05-30 16:00 → 2018-06-01 16:00 A (+2d) | 2018-05-30 17:00 → 2018-06-01 17:00 A (+2d) |  | 0% → 100% | 0.5d → none | baseline start 2018-05-30 16:00 → 2018-06-01 16:00; baseline finish 2018-05-30 17:00 → 2018-06-01 17:00 |
| 30 | Configure SOE on PCs | 2018-05-31 09:00 → 2018-06-05 09:00 A (+5d) | 2018-05-31 17:00 → 2018-06-05 17:00 A (+5d) |  | 0% → 100% | 0.5d → none | baseline start 2018-05-31 09:00 → 2018-06-05 09:00; baseline finish 2018-05-31 17:00 → 2018-06-05 17:00 |
| 31 | **Restructure Office** | 2018-05-23 06:00 → 2018-05-23 09:00 A | 2018-06-08 17:00 → 2018-06-18 09:00 A (+10d) | 13d → 18d | 0% → 100% | 0.5d → none | baseline start 2018-05-23 06:00 → 2018-05-23 09:00; baseline finish 2018-06-08 17:00 → 2018-06-18 09:00 |
| 32 | Erect New Walls | 2018-05-23 06:00 → 2018-05-23 09:00 A | 2018-05-25 07:00 → 2018-05-26 08:00 A (+1d) |  | 0% → 100% | 1d → none | baseline start 2018-05-23 06:00 → 2018-05-23 09:00; baseline finish 2018-05-25 07:00 → 2018-05-26 08:00 |
| 33 | Gyprock, Plaster & Finish | 2018-05-25 07:00 → 2018-05-29 09:00 A (+4d) | 2018-05-29 08:00 → 2018-06-02 13:00 A (+4d) |  | 0% → 100% | 1d → none | baseline start 2018-05-25 07:00 → 2018-05-29 09:00; baseline finish 2018-05-29 08:00 → 2018-06-02 13:00 |
| 34 | Install Network Points | 2018-06-01 09:00 → 2018-06-06 09:00 A (+5d) | 2018-06-01 15:00 → 2018-06-06 15:00 A (+5d) |  | 0% → 100% | 0.5d → none | baseline start 2018-06-01 09:00 → 2018-06-06 09:00; baseline finish 2018-06-01 15:00 → 2018-06-06 15:00 |
| 35 | Install Phone Connections | 2018-06-01 09:00 → 2018-06-06 09:00 A (+5d) | 2018-06-01 12:30 → 2018-06-06 12:30 A (+5d) |  | 0% → 100% | 0.5d → none | baseline start 2018-06-01 09:00 → 2018-06-06 09:00; baseline finish 2018-06-01 12:30 → 2018-06-06 12:30 |
| 36 | Re-Paint | 2018-06-02 07:00 → 2018-06-07 09:00 A (+5d) | 2018-06-02 15:00 → 2018-06-09 11:00 A (+7d) |  | 0% → 100% | 0d → none | baseline start 2018-06-02 07:00 → 2018-06-07 09:00; baseline finish 2018-06-02 15:00 → 2018-06-09 11:00 |
| 37 | Carpet | 2018-06-04 06:00 → 2018-06-11 09:00 A (+7d) | 2018-06-06 07:00 → 2018-06-14 07:00 A (+8d) |  | 0% → 100% | 0d → none | baseline start 2018-06-04 06:00 → 2018-06-11 09:00; baseline finish 2018-06-06 07:00 → 2018-06-14 07:00 |
| 38 | Install New Furniture | 2018-06-06 07:00 → 2018-06-13 09:00 A (+7d) | 2018-06-08 08:00 → 2018-06-16 08:00 A (+8d) |  | 0% → 100% | 0d → none | baseline start 2018-06-06 07:00 → 2018-06-13 09:00; baseline finish 2018-06-08 08:00 → 2018-06-16 08:00 |
| 39 | Install New PCs | 2018-06-08 09:00 → 2018-06-15 09:00 A (+7d) | 2018-06-08 17:00 → 2018-06-15 17:00 A (+7d) |  | 0% → 100% | 0.5d → none | baseline start 2018-06-08 09:00 → 2018-06-15 09:00; baseline finish 2018-06-08 17:00 → 2018-06-15 17:00 |
| 40 | Refit Office Complete | 2018-06-08 17:00 → 2018-06-18 09:00 A (+10d) | 2018-06-08 17:00 → 2018-06-18 09:00 A (+10d) |  | 0% → 100% | 0.5d → none | baseline start 2018-06-08 17:00 → 2018-06-18 09:00; baseline finish 2018-06-08 17:00 → 2018-06-18 09:00 |
| 41 | **Office Move** | 2018-05-31 09:00 → 2018-06-04 09:00 (+4d) | 2018-06-14 07:00 → 2018-06-21 07:00 (+7d) | 10d → 13d |  |  | baseline start 2018-05-31 09:00 → 2018-06-04 09:00; baseline finish 2018-06-14 07:00 → 2018-06-21 07:00 |
| 42 | Order packing boxes | 2018-05-31 09:00 → 2018-06-04 09:00 (+4d) | 2018-05-31 10:00 → 2018-06-04 10:00 (+4d) |  |  | 7.36d → 10.36d | baseline start 2018-05-31 09:00 → 2018-06-04 09:00; baseline finish 2018-05-31 10:00 → 2018-06-04 10:00 |
| 43 | Staff Pack | 2018-06-11 09:00 → 2018-06-18 09:00 (+7d) | 2018-06-11 12:30 → 2018-06-18 12:30 (+7d) |  |  |  | baseline start 2018-06-11 09:00 → 2018-06-18 09:00; baseline finish 2018-06-11 12:30 → 2018-06-18 12:30 |
| 44 | Staff Move | 2018-06-11 12:30 → 2018-06-18 12:30 (+7d) | 2018-06-14 07:00 → 2018-06-21 07:00 (+7d) |  |  |  | baseline start 2018-06-11 12:30 → 2018-06-18 12:30; baseline finish 2018-06-14 07:00 → 2018-06-21 07:00 |
| 45 | Office Move Complete | 2018-06-14 07:00 → 2018-06-21 07:00 (+7d) | 2018-06-14 07:00 → 2018-06-21 07:00 (+7d) |  |  |  | baseline start 2018-06-14 07:00 → 2018-06-21 07:00; baseline finish 2018-06-14 07:00 → 2018-06-21 07:00 |

## Version 7 (saved 2018-01-08, file Large Project.mpp)

Last finish 2018-06-21 → 2018-06-14 (-7d). Complete tasks 33 → 0.

Changed:

| ID | Task | Start | Finish | Duration | Complete | Total float | Other |
| --- | --- | --- | --- | --- | --- | --- | --- |
| 1 | **Planning & Research** | 2018-05-07 09:00 A → 2018-05-07 09:00 | 2018-05-17 12:00 A → 2018-05-17 12:00 |  | 100% → 0% | none → 0d | baseline start 2018-05-07 09:00 → 2011-04-04 09:00; baseline finish 2018-05-17 12:00 → 2011-04-14 12:00 |
| 2 | Develop Requirements Documentation | 2018-05-07 09:00 A → 2018-05-07 09:00 | 2018-05-07 17:00 A → 2018-05-07 17:00 |  | 100% → 0% | none → 0d | baseline start 2018-05-07 09:00 → 2011-04-04 09:00; baseline finish 2018-05-07 17:00 → 2011-04-04 17:00 |
| 3 | Fit-Out Consultant Research | 2018-05-08 09:00 A → 2018-05-08 09:00 | 2018-05-08 12:30 A → 2018-05-08 12:30 |  | 100% → 0% | none → 0.5d | baseline start 2018-05-08 09:00 → 2011-04-05 09:00; baseline finish 2018-05-08 12:30 → 2011-04-05 12:30 |
| 4 | Telecommunications Consultant Research | 2018-05-08 12:30 A → 2018-05-08 12:30 | 2018-05-08 17:00 A → 2018-05-08 17:00 |  | 100% → 0% | none → 0.5d | baseline start 2018-05-08 12:30 → 2011-04-05 12:30; baseline finish 2018-05-08 17:00 → 2011-04-05 17:00 |
| 5 | IT Network Contractor Research | 2018-05-09 09:00 A → 2018-05-09 09:00 | 2018-05-09 12:30 A → 2018-05-09 12:30 |  | 100% → 0% | none → 0.5d | baseline start 2018-05-09 09:00 → 2011-04-06 09:00; baseline finish 2018-05-09 12:30 → 2011-04-06 12:30 |
| 6 | Building Contractors Research | 2018-05-09 12:30 A → 2018-05-09 12:30 | 2018-05-09 17:00 A → 2018-05-09 17:00 |  | 100% → 0% | none → 0.5d | baseline start 2018-05-09 12:30 → 2011-04-06 12:30; baseline finish 2018-05-09 17:00 → 2011-04-06 17:00 |
| 7 | Submit Requirements to Resources & Request Quotes | 2018-05-10 09:00 A → 2018-05-10 09:00 | 2018-05-10 11:00 A → 2018-05-10 11:00 |  | 100% → 0% | none → 0.5d | baseline start 2018-05-10 09:00 → 2011-04-07 09:00; baseline finish 2018-05-10 11:00 → 2011-04-07 11:00 |
| 8 | Quotes Received | 2018-05-17 11:00 A → 2018-05-17 11:00 | 2018-05-17 12:00 A → 2018-05-17 12:00 |  | 100% → 0% | none → 0.5d | baseline start 2018-05-17 11:00 → 2011-04-14 11:00; baseline finish 2018-05-17 12:00 → 2011-04-14 12:00 |
| 9 | Planning & Research Complete | 2018-05-17 12:00 A → 2018-05-17 12:00 | 2018-05-17 12:00 A → 2018-05-17 12:00 |  | 100% → 0% | none → 0.5d | baseline start 2018-05-17 12:00 → 2011-04-14 12:00; baseline finish 2018-05-17 12:00 → 2011-04-14 12:00 |
| 10 | **Management Approval** | 2018-05-17 12:00 A → 2018-05-17 12:00 | 2018-05-21 10:30 A → 2018-05-21 10:30 |  | 100% → 0% | none → 0.5d | baseline start 2018-05-17 12:00 → 2011-04-14 12:00; baseline finish 2018-05-21 10:30 → 2011-04-15 15:00 |
| 11 | Consolidate Quotes and develop proposal | 2018-05-17 12:00 A → 2018-05-17 12:00 | 2018-05-18 16:30 A → 2018-05-18 16:30 |  | 100% → 0% | none → 0.5d | baseline start 2018-05-17 12:00 → 2011-04-14 12:00; baseline finish 2018-05-18 16:30 → 2011-04-15 12:00 |
| 12 | Develop Project Plan & Durations | 2018-05-18 16:30 A → 2018-05-18 16:30 | 2018-05-21 09:30 A → 2018-05-21 09:30 |  | 100% → 0% | none → 0.5d | baseline start 2018-05-18 16:30 → 2011-04-15 12:00; baseline finish 2018-05-21 09:30 → 2011-04-15 13:00 |
| 13 | Submit Project Plan & Costs to Management | 2018-05-21 09:30 A → 2018-05-21 09:30 | 2018-05-21 10:30 A → 2018-05-21 10:30 |  | 100% → 0% | none → 0.5d | baseline start 2018-05-21 09:30 → 2011-04-15 14:00; baseline finish 2018-05-21 10:30 → 2011-04-15 15:00 |
| 14 | Management Approval Received | 2018-05-21 10:30 A → 2018-05-21 10:30 | 2018-05-21 10:30 A → 2018-05-21 10:30 |  | 100% → 0% | none → 0.5d | baseline start 2018-05-21 10:30 → 2011-04-15 15:00; baseline finish 2018-05-21 10:30 → 2011-04-15 15:00 |
| 15 | **Refit Office** | 2018-05-21 10:30 A → 2018-05-21 10:30 | 2018-06-18 09:00 A → 2018-06-08 17:00 (-10d) | 19.79d → 14.79d | 100% → 0% | none → 0.5d | baseline start 2018-05-21 10:30 → 2011-04-15 15:00; baseline finish 2018-06-18 09:00 → 2011-05-11 17:00 |
| 16 | Appoint Resources | 2018-05-21 10:30 A → 2018-05-21 10:30 | 2018-05-21 12:30 A → 2018-05-21 12:30 |  | 100% → 0% | none → 0.5d | baseline start 2018-05-21 10:30 → 2011-04-15 15:00; baseline finish 2018-05-21 12:30 → 2011-04-15 17:00 |
| 17 | Staff Briefing | 2018-05-21 12:30 A → 2018-05-21 12:30 | 2018-05-21 14:30 A → 2018-05-21 14:30 |  | 100% → 0% | none → 0.5d | baseline start 2018-05-21 12:30 → 2011-04-18 09:00; baseline finish 2018-05-21 14:30 → 2011-04-18 10:00 |
| 18 | **Fit-Out Consultations** | 2018-05-21 14:30 A → 2018-05-21 14:30 | 2018-05-22 13:00 A → 2018-05-22 13:00 |  | 100% → 0% | none → 0.5d | baseline start 2018-05-21 14:30 → 2011-04-18 10:00; baseline finish 2018-05-22 13:00 → 2011-04-19 09:30 |
| 19 | Office Space / Structure Plan | 2018-05-21 14:30 A → 2018-05-21 14:30 | 2018-05-22 10:00 A → 2018-05-22 10:00 |  | 100% → 0% | none → 0.5d | baseline start 2018-05-21 14:30 → 2011-04-18 10:00; baseline finish 2018-05-22 10:00 → 2011-04-18 14:30 |
| 20 | Select & Order Carpet | 2018-05-22 10:00 A → 2018-05-22 10:00 | 2018-05-22 11:00 A → 2018-05-22 11:00 |  | 100% → 0% | none → 0.5d | baseline start 2018-05-22 10:00 → 2011-04-18 14:30; baseline finish 2018-05-22 11:00 → 2011-04-18 15:30 |
| 21 | Select & Order Paint | 2018-05-22 11:00 A → 2018-05-22 11:00 | 2018-05-22 12:00 A → 2018-05-22 12:00 |  | 100% → 0% | none → 0.5d | baseline start 2018-05-22 11:00 → 2011-04-18 15:30; baseline finish 2018-05-22 12:00 → 2011-04-18 16:30 |
| 22 | Select & Order Office Furniture | 2018-05-22 12:00 A → 2018-05-22 12:00 | 2018-05-22 13:00 A → 2018-05-22 13:00 |  | 100% → 0% | none → 0.5d | baseline start 2018-05-22 12:00 → 2011-04-18 16:30; baseline finish 2018-05-22 13:00 → 2011-04-19 09:30 |
| 23 | **Telecommuncations Consultations** | 2018-05-22 14:00 A → 2018-05-22 14:00 | 2018-05-23 10:30 A → 2018-05-23 10:30 |  | 100% → 0% | none → 0.5d | baseline start 2018-05-22 14:00 → 2011-04-19 09:30; baseline finish 2018-05-23 10:30 → 2011-04-19 15:00 |
| 24 | Design Telephone Access Points Map | 2018-05-22 14:00 A → 2018-05-22 14:00 | 2018-05-23 09:30 A → 2018-05-23 09:30 |  | 100% → 0% | none → 0.5d | baseline start 2018-05-22 14:00 → 2011-04-19 09:30; baseline finish 2018-05-23 09:30 → 2011-04-19 13:00 |
| 25 | Select & Order New PABX | 2018-05-23 09:30 A → 2018-05-23 09:30 | 2018-05-23 10:30 A → 2018-05-23 10:30 |  | 100% → 0% | none → 0.5d | baseline start 2018-05-23 09:30 → 2011-04-19 14:00; baseline finish 2018-05-23 10:30 → 2011-04-19 15:00 |
| 26 | **IT Networking Consultations** | 2018-05-23 10:30 A → 2018-05-23 10:30 | 2018-06-05 17:00 A → 2018-05-31 17:00 (-5d) | 9.79d → 6.79d | 100% → 0% | none → 0.5d | baseline start 2018-05-23 10:30 → 2011-04-19 15:00; baseline finish 2018-06-05 17:00 → 2011-05-03 12:30 |
| 27 | Design Network Access Points Map | 2018-05-23 10:30 A → 2018-05-23 10:30 | 2018-05-23 15:00 A → 2018-05-23 15:00 |  | 100% → 0% | none → 0.5d | baseline start 2018-05-23 10:30 → 2011-04-19 15:00; baseline finish 2018-05-23 15:00 → 2011-04-20 10:30 |
| 28 | Select & Order New PCs | 2018-05-23 15:00 A → 2018-05-23 15:00 | 2018-05-23 16:00 A → 2018-05-23 16:00 |  | 100% → 0% | none → 0.5d | baseline start 2018-05-23 15:00 → 2011-04-20 10:30; baseline finish 2018-05-23 16:00 → 2011-04-20 11:30 |
| 29 | New PCs Arrive | 2018-06-01 16:00 A → 2018-05-30 16:00 (-2d) | 2018-06-01 17:00 A → 2018-05-30 17:00 (-2d) |  | 100% → 0% | none → 0.5d | baseline start 2018-06-01 16:00 → 2011-04-29 11:30; baseline finish 2018-06-01 17:00 → 2011-04-29 12:30 |
| 30 | Configure SOE on PCs | 2018-06-05 09:00 A → 2018-05-31 09:00 (-5d) | 2018-06-05 17:00 A → 2018-05-31 17:00 (-5d) |  | 100% → 0% | none → 0.5d | baseline start 2018-06-05 09:00 → 2011-04-29 12:30; baseline finish 2018-06-05 17:00 → 2011-05-03 12:30 |
| 31 | **Restructure Office** | 2018-05-23 09:00 A → 2018-05-23 06:00 | 2018-06-18 09:00 A → 2018-06-08 17:00 (-10d) | 18d → 13d | 100% → 0% | none → 0.5d | baseline start 2018-05-23 09:00 → 2011-04-20 06:00; baseline finish 2018-06-18 09:00 → 2011-05-11 17:00 |
| 32 | Erect New Walls | 2018-05-23 09:00 A → 2018-05-23 06:00 | 2018-05-26 08:00 A → 2018-05-25 07:00 (-1d) |  | 100% → 0% | none → 1d | baseline start 2018-05-23 09:00 → 2011-04-20 06:00; baseline finish 2018-05-26 08:00 → 2011-04-26 07:00 |
| 33 | Gyprock, Plaster & Finish | 2018-05-29 09:00 A → 2018-05-25 07:00 (-4d) | 2018-06-02 13:00 A → 2018-05-29 08:00 (-4d) |  | 100% → 0% | none → 1d | baseline start 2018-05-29 09:00 → 2011-04-26 07:00; baseline finish 2018-06-02 13:00 → 2011-04-30 10:00 |
| 34 | Install Network Points | 2018-06-06 09:00 A → 2018-06-01 09:00 (-5d) | 2018-06-06 15:00 A → 2018-06-01 15:00 (-5d) |  | 100% → 0% | none → 0.5d | baseline start 2018-06-06 09:00 → 2011-05-03 12:30; baseline finish 2018-06-06 15:00 → 2011-05-04 10:30 |
| 35 | Install Phone Connections | 2018-06-06 09:00 A → 2018-06-01 09:00 (-5d) | 2018-06-06 12:30 A → 2018-06-01 12:30 (-5d) |  | 100% → 0% | none → 0.5d | baseline start 2018-06-06 09:00 → 2011-05-03 12:30; baseline finish 2018-06-06 12:30 → 2011-05-03 17:00 |
| 36 | Re-Paint | 2018-06-07 09:00 A → 2018-06-02 07:00 (-5d) | 2018-06-09 11:00 A → 2018-06-02 15:00 (-7d) |  | 100% → 0% | none → 0d | baseline start 2018-06-07 09:00 → 2011-05-04 06:00; baseline finish 2018-06-09 11:00 → 2011-05-06 07:00 |
| 37 | Carpet | 2018-06-11 09:00 A → 2018-06-04 06:00 (-7d) | 2018-06-14 07:00 A → 2018-06-06 07:00 (-8d) |  | 100% → 0% | none → 0d | baseline start 2018-06-11 09:00 → 2011-05-07 07:00; baseline finish 2018-06-14 07:00 → 2011-05-07 15:00 |
| 38 | Install New Furniture | 2018-06-13 09:00 A → 2018-06-06 07:00 (-7d) | 2018-06-16 08:00 A → 2018-06-08 08:00 (-8d) |  | 100% → 0% | none → 0d | baseline start 2018-06-13 09:00 → 2011-05-09 06:00; baseline finish 2018-06-16 08:00 → 2011-05-11 07:00 |
| 39 | Install New PCs | 2018-06-15 09:00 A → 2018-06-08 09:00 (-7d) | 2018-06-15 17:00 A → 2018-06-08 17:00 (-7d) |  | 100% → 0% | none → 0.5d | baseline start 2018-06-15 09:00 → 2011-05-11 09:00; baseline finish 2018-06-15 17:00 → 2011-05-11 17:00 |
| 40 | Refit Office Complete | 2018-06-18 09:00 A → 2018-06-08 17:00 (-10d) | 2018-06-18 09:00 A → 2018-06-08 17:00 (-10d) |  | 100% → 0% | none → 0.5d | baseline start 2018-06-18 09:00 → 2011-05-11 17:00; baseline finish 2018-06-18 09:00 → 2011-05-11 17:00 |
| 41 | **Office Move** | 2018-06-04 09:00 → 2018-05-31 09:00 (-4d) | 2018-06-21 07:00 → 2018-06-14 07:00 (-7d) | 13d → 10d |  |  | baseline start 2018-06-04 09:00 → 2011-04-29 12:30; baseline finish 2018-06-21 07:00 → 2011-05-16 17:00 |
| 42 | Order packing boxes | 2018-06-04 09:00 → 2018-05-31 09:00 (-4d) | 2018-06-04 10:00 → 2018-05-31 10:00 (-4d) |  |  | 10.36d → 7.36d | baseline start 2018-06-04 09:00 → 2011-04-29 12:30; baseline finish 2018-06-04 10:00 → 2011-04-29 14:30 |
| 43 | Staff Pack | 2018-06-18 09:00 → 2018-06-11 09:00 (-7d) | 2018-06-18 12:30 → 2018-06-11 12:30 (-7d) |  |  |  | baseline start 2018-06-18 09:00 → 2011-05-12 09:00; baseline finish 2018-06-18 12:30 → 2011-05-12 12:30 |
| 44 | Staff Move | 2018-06-18 12:30 → 2018-06-11 12:30 (-7d) | 2018-06-21 07:00 → 2018-06-14 07:00 (-7d) |  |  |  | baseline start 2018-06-18 12:30 → 2011-05-12 12:30; baseline finish 2018-06-21 07:00 → 2011-05-14 11:00 |
| 45 | Office Move Complete | 2018-06-21 07:00 → 2018-06-14 07:00 (-7d) | 2018-06-21 07:00 → 2018-06-14 07:00 (-7d) |  |  |  | constraint finish no later than 2018-06-22 19:00 → none; baseline start 2018-06-21 07:00 → 2011-05-16 17:00; baseline finish 2018-06-21 07:00 → 2011-05-16 17:00 |

## Version 8 (saved 2018-01-08, file Pivots.mpp)

Last finish 2018-06-14 → 2018-06-21 (+7d). Complete tasks 0 → 33.

Changed:

| ID | Task | Start | Finish | Duration | Complete | Total float | Other |
| --- | --- | --- | --- | --- | --- | --- | --- |
| 1 | **Planning & Research** | 2018-05-07 09:00 A | 2018-05-17 12:00 A |  | 0% → 100% | 0d → none | baseline start 2011-04-04 09:00 → 2018-05-07 09:00; baseline finish 2011-04-14 12:00 → 2018-05-17 12:00 |
| 2 | Develop Requirements Documentation | 2018-05-07 09:00 A | 2018-05-07 17:00 A |  | 0% → 100% | 0d → none | baseline start 2011-04-04 09:00 → 2018-05-07 09:00; baseline finish 2011-04-04 17:00 → 2018-05-07 17:00 |
| 3 | Fit-Out Consultant Research | 2018-05-08 09:00 A | 2018-05-08 12:30 A |  | 0% → 100% | 0.5d → none | baseline start 2011-04-05 09:00 → 2018-05-08 09:00; baseline finish 2011-04-05 12:30 → 2018-05-08 12:30 |
| 4 | Telecommunications Consultant Research | 2018-05-08 12:30 A | 2018-05-08 17:00 A |  | 0% → 100% | 0.5d → none | baseline start 2011-04-05 12:30 → 2018-05-08 12:30; baseline finish 2011-04-05 17:00 → 2018-05-08 17:00 |
| 5 | IT Network Contractor Research | 2018-05-09 09:00 A | 2018-05-09 12:30 A |  | 0% → 100% | 0.5d → none | baseline start 2011-04-06 09:00 → 2018-05-09 09:00; baseline finish 2011-04-06 12:30 → 2018-05-09 12:30 |
| 6 | Building Contractors Research | 2018-05-09 12:30 A | 2018-05-09 17:00 A |  | 0% → 100% | 0.5d → none | baseline start 2011-04-06 12:30 → 2018-05-09 12:30; baseline finish 2011-04-06 17:00 → 2018-05-09 17:00 |
| 7 | Submit Requirements to Resources & Request Quotes | 2018-05-10 09:00 A | 2018-05-10 11:00 A |  | 0% → 100% | 0.5d → none | baseline start 2011-04-07 09:00 → 2018-05-10 09:00; baseline finish 2011-04-07 11:00 → 2018-05-10 11:00 |
| 8 | Quotes Received | 2018-05-17 11:00 A | 2018-05-17 12:00 A |  | 0% → 100% | 0.5d → none | baseline start 2011-04-14 11:00 → 2018-05-17 11:00; baseline finish 2011-04-14 12:00 → 2018-05-17 12:00 |
| 9 | Planning & Research Complete | 2018-05-17 12:00 A | 2018-05-17 12:00 A |  | 0% → 100% | 0.5d → none | baseline start 2011-04-14 12:00 → 2018-05-17 12:00; baseline finish 2011-04-14 12:00 → 2018-05-17 12:00 |
| 10 | **Management Approval** | 2018-05-17 12:00 A | 2018-05-21 10:30 A |  | 0% → 100% | 0.5d → none | baseline start 2011-04-14 12:00 → 2018-05-17 12:00; baseline finish 2011-04-15 15:00 → 2018-05-21 10:30 |
| 11 | Consolidate Quotes and develop proposal | 2018-05-17 12:00 A | 2018-05-18 16:30 A |  | 0% → 100% | 0.5d → none | baseline start 2011-04-14 12:00 → 2018-05-17 12:00; baseline finish 2011-04-15 12:00 → 2018-05-18 16:30 |
| 12 | Develop Project Plan & Durations | 2018-05-18 16:30 A | 2018-05-21 09:30 A |  | 0% → 100% | 0.5d → none | baseline start 2011-04-15 12:00 → 2018-05-18 16:30; baseline finish 2011-04-15 13:00 → 2018-05-21 09:30 |
| 13 | Submit Project Plan & Costs to Management | 2018-05-21 09:30 A | 2018-05-21 10:30 A |  | 0% → 100% | 0.5d → none | baseline start 2011-04-15 14:00 → 2018-05-21 09:30; baseline finish 2011-04-15 15:00 → 2018-05-21 10:30 |
| 14 | Management Approval Received | 2018-05-21 10:30 A | 2018-05-21 10:30 A |  | 0% → 100% | 0.5d → none | baseline start 2011-04-15 15:00 → 2018-05-21 10:30; baseline finish 2011-04-15 15:00 → 2018-05-21 10:30 |
| 15 | **Refit Office** | 2018-05-21 10:30 A | 2018-06-08 17:00 → 2018-06-18 09:00 A (+10d) | 14.79d → 19.79d | 0% → 100% | 0.5d → none | baseline start 2011-04-15 15:00 → 2018-05-21 10:30; baseline finish 2011-05-11 17:00 → 2018-06-18 09:00 |
| 16 | Appoint Resources | 2018-05-21 10:30 A | 2018-05-21 12:30 A |  | 0% → 100% | 0.5d → none | baseline start 2011-04-15 15:00 → 2018-05-21 10:30; baseline finish 2011-04-15 17:00 → 2018-05-21 12:30 |
| 17 | Staff Briefing | 2018-05-21 12:30 A | 2018-05-21 14:30 A |  | 0% → 100% | 0.5d → none | baseline start 2011-04-18 09:00 → 2018-05-21 12:30; baseline finish 2011-04-18 10:00 → 2018-05-21 14:30 |
| 18 | **Fit-Out Consultations** | 2018-05-21 14:30 A | 2018-05-22 13:00 A |  | 0% → 100% | 0.5d → none | baseline start 2011-04-18 10:00 → 2018-05-21 14:30; baseline finish 2011-04-19 09:30 → 2018-05-22 13:00 |
| 19 | Office Space / Structure Plan | 2018-05-21 14:30 A | 2018-05-22 10:00 A |  | 0% → 100% | 0.5d → none | baseline start 2011-04-18 10:00 → 2018-05-21 14:30; baseline finish 2011-04-18 14:30 → 2018-05-22 10:00 |
| 20 | Select & Order Carpet | 2018-05-22 10:00 A | 2018-05-22 11:00 A |  | 0% → 100% | 0.5d → none | baseline start 2011-04-18 14:30 → 2018-05-22 10:00; baseline finish 2011-04-18 15:30 → 2018-05-22 11:00 |
| 21 | Select & Order Paint | 2018-05-22 11:00 A | 2018-05-22 12:00 A |  | 0% → 100% | 0.5d → none | baseline start 2011-04-18 15:30 → 2018-05-22 11:00; baseline finish 2011-04-18 16:30 → 2018-05-22 12:00 |
| 22 | Select & Order Office Furniture | 2018-05-22 12:00 A | 2018-05-22 13:00 A |  | 0% → 100% | 0.5d → none | baseline start 2011-04-18 16:30 → 2018-05-22 12:00; baseline finish 2011-04-19 09:30 → 2018-05-22 13:00 |
| 23 | **Telecommuncations Consultations** | 2018-05-22 14:00 A | 2018-05-23 10:30 A |  | 0% → 100% | 0.5d → none | baseline start 2011-04-19 09:30 → 2018-05-22 14:00; baseline finish 2011-04-19 15:00 → 2018-05-23 10:30 |
| 24 | Design Telephone Access Points Map | 2018-05-22 14:00 A | 2018-05-23 09:30 A |  | 0% → 100% | 0.5d → none | baseline start 2011-04-19 09:30 → 2018-05-22 14:00; baseline finish 2011-04-19 13:00 → 2018-05-23 09:30 |
| 25 | Select & Order New PABX | 2018-05-23 09:30 A | 2018-05-23 10:30 A |  | 0% → 100% | 0.5d → none | baseline start 2011-04-19 14:00 → 2018-05-23 09:30; baseline finish 2011-04-19 15:00 → 2018-05-23 10:30 |
| 26 | **IT Networking Consultations** | 2018-05-23 10:30 A | 2018-05-31 17:00 → 2018-06-05 17:00 A (+5d) | 6.79d → 9.79d | 0% → 100% | 0.5d → none | baseline start 2011-04-19 15:00 → 2018-05-23 10:30; baseline finish 2011-05-03 12:30 → 2018-06-05 17:00 |
| 27 | Design Network Access Points Map | 2018-05-23 10:30 A | 2018-05-23 15:00 A |  | 0% → 100% | 0.5d → none | baseline start 2011-04-19 15:00 → 2018-05-23 10:30; baseline finish 2011-04-20 10:30 → 2018-05-23 15:00 |
| 28 | Select & Order New PCs | 2018-05-23 15:00 A | 2018-05-23 16:00 A |  | 0% → 100% | 0.5d → none | baseline start 2011-04-20 10:30 → 2018-05-23 15:00; baseline finish 2011-04-20 11:30 → 2018-05-23 16:00 |
| 29 | New PCs Arrive | 2018-05-30 16:00 → 2018-06-01 16:00 A (+2d) | 2018-05-30 17:00 → 2018-06-01 17:00 A (+2d) |  | 0% → 100% | 0.5d → none | baseline start 2011-04-29 11:30 → 2018-06-01 16:00; baseline finish 2011-04-29 12:30 → 2018-06-01 17:00 |
| 30 | Configure SOE on PCs | 2018-05-31 09:00 → 2018-06-05 09:00 A (+5d) | 2018-05-31 17:00 → 2018-06-05 17:00 A (+5d) |  | 0% → 100% | 0.5d → none | baseline start 2011-04-29 12:30 → 2018-06-05 09:00; baseline finish 2011-05-03 12:30 → 2018-06-05 17:00 |
| 31 | **Restructure Office** | 2018-05-23 06:00 → 2018-05-23 09:00 A | 2018-06-08 17:00 → 2018-06-18 09:00 A (+10d) | 13d → 18d | 0% → 100% | 0.5d → none | baseline start 2011-04-20 06:00 → 2018-05-23 09:00; baseline finish 2011-05-11 17:00 → 2018-06-18 09:00 |
| 32 | Erect New Walls | 2018-05-23 06:00 → 2018-05-23 09:00 A | 2018-05-25 07:00 → 2018-05-26 08:00 A (+1d) |  | 0% → 100% | 1d → none | baseline start 2011-04-20 06:00 → 2018-05-23 09:00; baseline finish 2011-04-26 07:00 → 2018-05-26 08:00 |
| 33 | Gyprock, Plaster & Finish | 2018-05-25 07:00 → 2018-05-29 09:00 A (+4d) | 2018-05-29 08:00 → 2018-06-02 13:00 A (+4d) |  | 0% → 100% | 1d → none | baseline start 2011-04-26 07:00 → 2018-05-29 09:00; baseline finish 2011-04-30 10:00 → 2018-06-02 13:00 |
| 34 | Install Network Points | 2018-06-01 09:00 → 2018-06-06 09:00 A (+5d) | 2018-06-01 15:00 → 2018-06-06 15:00 A (+5d) |  | 0% → 100% | 0.5d → none | baseline start 2011-05-03 12:30 → 2018-06-06 09:00; baseline finish 2011-05-04 10:30 → 2018-06-06 15:00 |
| 35 | Install Phone Connections | 2018-06-01 09:00 → 2018-06-06 09:00 A (+5d) | 2018-06-01 12:30 → 2018-06-06 12:30 A (+5d) |  | 0% → 100% | 0.5d → none | baseline start 2011-05-03 12:30 → 2018-06-06 09:00; baseline finish 2011-05-03 17:00 → 2018-06-06 12:30 |
| 36 | Re-Paint | 2018-06-02 07:00 → 2018-06-07 09:00 A (+5d) | 2018-06-02 15:00 → 2018-06-09 11:00 A (+7d) |  | 0% → 100% | 0d → none | baseline start 2011-05-04 06:00 → 2018-06-07 09:00; baseline finish 2011-05-06 07:00 → 2018-06-09 11:00 |
| 37 | Carpet | 2018-06-04 06:00 → 2018-06-11 09:00 A (+7d) | 2018-06-06 07:00 → 2018-06-14 07:00 A (+8d) |  | 0% → 100% | 0d → none | baseline start 2011-05-07 07:00 → 2018-06-11 09:00; baseline finish 2011-05-07 15:00 → 2018-06-14 07:00 |
| 38 | Install New Furniture | 2018-06-06 07:00 → 2018-06-13 09:00 A (+7d) | 2018-06-08 08:00 → 2018-06-16 08:00 A (+8d) |  | 0% → 100% | 0d → none | baseline start 2011-05-09 06:00 → 2018-06-13 09:00; baseline finish 2011-05-11 07:00 → 2018-06-16 08:00 |
| 39 | Install New PCs | 2018-06-08 09:00 → 2018-06-15 09:00 A (+7d) | 2018-06-08 17:00 → 2018-06-15 17:00 A (+7d) |  | 0% → 100% | 0.5d → none | baseline start 2011-05-11 09:00 → 2018-06-15 09:00; baseline finish 2011-05-11 17:00 → 2018-06-15 17:00 |
| 40 | Refit Office Complete | 2018-06-08 17:00 → 2018-06-18 09:00 A (+10d) | 2018-06-08 17:00 → 2018-06-18 09:00 A (+10d) |  | 0% → 100% | 0.5d → none | baseline start 2011-05-11 17:00 → 2018-06-18 09:00; baseline finish 2011-05-11 17:00 → 2018-06-18 09:00 |
| 41 | **Office Move** | 2018-05-31 09:00 → 2018-06-04 09:00 (+4d) | 2018-06-14 07:00 → 2018-06-21 07:00 (+7d) | 10d → 13d |  |  | baseline start 2011-04-29 12:30 → 2018-06-04 09:00; baseline finish 2011-05-16 17:00 → 2018-06-21 07:00 |
| 42 | Order packing boxes | 2018-05-31 09:00 → 2018-06-04 09:00 (+4d) | 2018-05-31 10:00 → 2018-06-04 10:00 (+4d) |  |  | 7.36d → 10.36d | baseline start 2011-04-29 12:30 → 2018-06-04 09:00; baseline finish 2011-04-29 14:30 → 2018-06-04 10:00 |
| 43 | Staff Pack | 2018-06-11 09:00 → 2018-06-18 09:00 (+7d) | 2018-06-11 12:30 → 2018-06-18 12:30 (+7d) |  |  |  | baseline start 2011-05-12 09:00 → 2018-06-18 09:00; baseline finish 2011-05-12 12:30 → 2018-06-18 12:30 |
| 44 | Staff Move | 2018-06-11 12:30 → 2018-06-18 12:30 (+7d) | 2018-06-14 07:00 → 2018-06-21 07:00 (+7d) |  |  |  | baseline start 2011-05-12 12:30 → 2018-06-18 12:30; baseline finish 2011-05-14 11:00 → 2018-06-21 07:00 |
| 45 | Office Move Complete | 2018-06-14 07:00 → 2018-06-21 07:00 (+7d) | 2018-06-14 07:00 → 2018-06-21 07:00 (+7d) |  |  |  | constraint none → finish no later than 2018-06-22 19:00; baseline start 2011-05-16 17:00 → 2018-06-21 07:00; baseline finish 2011-05-16 17:00 → 2018-06-21 07:00 |

## Version 9 (saved 2018-01-08, file Sharing Resources 2.mpp)

Last finish 2018-06-21 → 2018-06-26 (+5d). Complete tasks 33 → 0.

Changed:

| ID | Task | Start | Finish | Duration | Complete | Total float | Other |
| --- | --- | --- | --- | --- | --- | --- | --- |
| 1 | **Planning & Research** | 2018-05-07 09:00 A → 2018-05-14 08:00 (+7d) | 2018-05-17 12:00 A → 2018-05-23 11:00 (+6d) |  | 100% → 0% | none → 0.14d | baseline start 2018-05-07 09:00 → 2011-04-04 09:00; baseline finish 2018-05-17 12:00 → 2011-04-14 12:00 |
| 2 | Develop Requirements Documentation | 2018-05-07 09:00 A → 2018-05-14 08:00 (+7d) | 2018-05-07 17:00 A → 2018-05-14 16:00 (+7d) |  | 100% → 0% | none → 0.14d | resources Project Manager → none; baseline start 2018-05-07 09:00 → 2011-04-04 09:00; baseline finish 2018-05-07 17:00 → 2011-04-04 17:00 |
| 3 | Fit-Out Consultant Research | 2018-05-08 09:00 A → 2018-05-14 16:00 (+6d) | 2018-05-08 12:30 A → 2018-05-15 10:30 (+7d) |  | 100% → 0% | none → 8.29d | resources Project Manager → none; baseline start 2018-05-08 09:00 → 2011-04-05 09:00; baseline finish 2018-05-08 12:30 → 2011-04-05 12:30 |
| 4 | Telecommunications Consultant Research | 2018-05-08 12:30 A → 2018-05-15 10:30 (+7d) | 2018-05-08 17:00 A → 2018-05-15 15:00 (+7d) |  | 100% → 0% | none → 8.29d | resources Project Manager → none; baseline start 2018-05-08 12:30 → 2011-04-05 12:30; baseline finish 2018-05-08 17:00 → 2011-04-05 17:00 |
| 5 | IT Network Contractor Research | 2018-05-09 09:00 A → 2018-05-15 15:00 (+6d) | 2018-05-09 12:30 A → 2018-05-16 09:30 (+7d) |  | 100% → 0% | none → 8.29d | resources Project Manager → none; baseline start 2018-05-09 09:00 → 2011-04-06 09:00; baseline finish 2018-05-09 12:30 → 2011-04-06 12:30 |
| 6 | Building Contractors Research | 2018-05-09 12:30 A → 2018-05-16 09:30 (+7d) | 2018-05-09 17:00 A → 2018-05-16 14:00 (+7d) |  | 100% → 0% | none → 8.29d | resources Project Manager → none; baseline start 2018-05-09 12:30 → 2011-04-06 12:30; baseline finish 2018-05-09 17:00 → 2011-04-06 17:00 |
| 7 | Submit Requirements to Resources & Request Quotes | 2018-05-10 09:00 A → 2018-05-16 14:00 (+6d) | 2018-05-10 11:00 A → 2018-05-16 16:00 (+6d) |  | 100% → 0% | none → 8.29d | resources Project Manager → none; baseline start 2018-05-10 09:00 → 2011-04-07 09:00; baseline finish 2018-05-10 11:00 → 2011-04-07 11:00 |
| 8 | Quotes Received | 2018-05-17 11:00 A → 2018-05-23 10:00 (+6d) | 2018-05-17 12:00 A → 2018-05-23 11:00 (+6d) |  | 100% → 0% | none → 8.29d | resources Project Manager → none; baseline start 2018-05-17 11:00 → 2011-04-14 11:00; baseline finish 2018-05-17 12:00 → 2011-04-14 12:00 |
| 9 | Planning & Research Complete | 2018-05-17 12:00 A → 2018-05-23 11:00 (+6d) | 2018-05-17 12:00 A → 2018-05-23 11:00 (+6d) |  | 100% → 0% | none → 8.29d | baseline start 2018-05-17 12:00 → 2011-04-14 12:00; baseline finish 2018-05-17 12:00 → 2011-04-14 12:00 |
| 10 | **Management Approval** | 2018-05-17 12:00 A → 2018-05-23 11:00 (+6d) | 2018-05-21 10:30 A → 2018-05-24 16:30 (+3d) |  | 100% → 0% | none → 8.29d | baseline start 2018-05-17 12:00 → 2011-04-14 12:00; baseline finish 2018-05-21 10:30 → 2011-04-15 15:00 |
| 11 | Consolidate Quotes and develop proposal | 2018-05-17 12:00 A → 2018-05-23 11:00 (+6d) | 2018-05-18 16:30 A → 2018-05-24 14:30 (+6d) |  | 100% → 0% | none → 8.29d | resources Project Manager → none; baseline start 2018-05-17 12:00 → 2011-04-14 12:00; baseline finish 2018-05-18 16:30 → 2011-04-15 12:00 |
| 12 | Develop Project Plan & Durations | 2018-05-18 16:30 A → 2018-05-24 14:30 (+6d) | 2018-05-21 09:30 A → 2018-05-24 15:30 (+3d) |  | 100% → 0% | none → 8.29d | resources Project Manager → none; baseline start 2018-05-18 16:30 → 2011-04-15 12:00; baseline finish 2018-05-21 09:30 → 2011-04-15 13:00 |
| 13 | Submit Project Plan & Costs to Management | 2018-05-21 09:30 A → 2018-05-24 15:30 (+3d) | 2018-05-21 10:30 A → 2018-05-24 16:30 (+3d) |  | 100% → 0% | none → 8.29d | resources Project Manager; Management → none; baseline start 2018-05-21 09:30 → 2011-04-15 14:00; baseline finish 2018-05-21 10:30 → 2011-04-15 15:00 |
| 14 | Management Approval Received | 2018-05-21 10:30 A → 2018-05-24 16:30 (+3d) | 2018-05-21 10:30 A → 2018-05-24 16:30 (+3d) |  | 100% → 0% | none → 8.29d | baseline start 2018-05-21 10:30 → 2011-04-15 15:00; baseline finish 2018-05-21 10:30 → 2011-04-15 15:00 |
| 15 | **Refit Office** | 2018-05-21 10:30 A → 2018-05-24 16:30 (+3d) | 2018-06-18 09:00 A → 2018-06-12 13:30 (-6d) | 19.79d → 14.43d | 100% → 0% | none → 8.29d | baseline start 2018-05-21 10:30 → 2011-04-15 15:00; baseline finish 2018-06-18 09:00 → 2011-05-11 17:00 |
| 16 | Appoint Resources | 2018-05-21 10:30 A → 2018-05-24 16:30 (+3d) | 2018-05-21 12:30 A → 2018-05-25 09:30 (+4d) |  | 100% → 0% | none → 8.29d | resources Project Manager → none; baseline start 2018-05-21 10:30 → 2011-04-15 15:00; baseline finish 2018-05-21 12:30 → 2011-04-15 17:00 |
| 17 | Staff Briefing | 2018-05-21 12:30 A → 2018-05-25 09:30 (+4d) | 2018-05-21 14:30 A → 2018-05-25 10:30 (+4d) |  | 100% → 0% | none → 8.29d | resources Project Manager; Staff [700%] → none; baseline start 2018-05-21 12:30 → 2011-04-18 09:00; baseline finish 2018-05-21 14:30 → 2011-04-18 10:00 |
| 18 | **Fit-Out Consultations** | 2018-05-21 14:30 A → 2018-05-25 10:30 (+4d) | 2018-05-22 13:00 A → 2018-05-28 09:00 (+6d) |  | 100% → 0% | none → 8.29d | baseline start 2018-05-21 14:30 → 2011-04-18 10:00; baseline finish 2018-05-22 13:00 → 2011-04-19 09:30 |
| 19 | Office Space / Structure Plan | 2018-05-21 14:30 A → 2018-05-25 10:30 (+4d) | 2018-05-22 10:00 A → 2018-05-25 15:00 (+3d) |  | 100% → 0% | none → 8.29d | resources Fit-out Consultant; Project Manager → none; baseline start 2018-05-21 14:30 → 2011-04-18 10:00; baseline finish 2018-05-22 10:00 → 2011-04-18 14:30 |
| 20 | Select & Order Carpet | 2018-05-22 10:00 A → 2018-05-25 15:00 (+3d) | 2018-05-22 11:00 A → 2018-05-25 16:00 (+3d) |  | 100% → 0% | none → 8.29d | resources Fit-out Consultant; Project Manager → none; baseline start 2018-05-22 10:00 → 2011-04-18 14:30; baseline finish 2018-05-22 11:00 → 2011-04-18 15:30 |
| 21 | Select & Order Paint | 2018-05-22 11:00 A → 2018-05-25 16:00 (+3d) | 2018-05-22 12:00 A → 2018-05-25 17:00 (+3d) |  | 100% → 0% | none → 8.29d | resources Fit-out Consultant; Project Manager → none; baseline start 2018-05-22 11:00 → 2011-04-18 15:30; baseline finish 2018-05-22 12:00 → 2011-04-18 16:30 |
| 22 | Select & Order Office Furniture | 2018-05-22 12:00 A → 2018-05-28 08:00 (+6d) | 2018-05-22 13:00 A → 2018-05-28 09:00 (+6d) |  | 100% → 0% | none → 8.29d | resources Fit-out Consultant; Project Manager → none; baseline start 2018-05-22 12:00 → 2011-04-18 16:30; baseline finish 2018-05-22 13:00 → 2011-04-19 09:30 |
| 23 | **Telecommuncations Consultations** | 2018-05-22 14:00 A → 2018-05-28 09:00 (+6d) | 2018-05-23 10:30 A → 2018-05-28 14:30 (+5d) |  | 100% → 0% | none → 8.29d | baseline start 2018-05-22 14:00 → 2011-04-19 09:30; baseline finish 2018-05-23 10:30 → 2011-04-19 15:00 |
| 24 | Design Telephone Access Points Map | 2018-05-22 14:00 A → 2018-05-28 09:00 (+6d) | 2018-05-23 09:30 A → 2018-05-28 13:30 (+5d) |  | 100% → 0% | none → 8.29d | resources Project Manager; Telecommunications consultant → none; baseline start 2018-05-22 14:00 → 2011-04-19 09:30; baseline finish 2018-05-23 09:30 → 2011-04-19 13:00 |
| 25 | Select & Order New PABX | 2018-05-23 09:30 A → 2018-05-28 13:30 (+5d) | 2018-05-23 10:30 A → 2018-05-28 14:30 (+5d) |  | 100% → 0% | none → 8.29d | resources Project Manager → none; baseline start 2018-05-23 09:30 → 2011-04-19 14:00; baseline finish 2018-05-23 10:30 → 2011-04-19 15:00 |
| 26 | **IT Networking Consultations** | 2018-05-23 10:30 A → 2018-05-28 14:30 (+5d) | 2018-06-05 17:00 A → 2018-06-05 14:00 | 9.79d → 6.79d | 100% → 0% | none → 8.29d | baseline start 2018-05-23 10:30 → 2011-04-19 15:00; baseline finish 2018-06-05 17:00 → 2011-05-03 12:30 |
| 27 | Design Network Access Points Map | 2018-05-23 10:30 A → 2018-05-28 14:30 (+5d) | 2018-05-23 15:00 A → 2018-05-29 09:00 (+6d) |  | 100% → 0% | none → 8.29d | resources IT Consultant; Project Manager → none; baseline start 2018-05-23 10:30 → 2011-04-19 15:00; baseline finish 2018-05-23 15:00 → 2011-04-20 10:30 |
| 28 | Select & Order New PCs | 2018-05-23 15:00 A → 2018-05-29 09:00 (+6d) | 2018-05-23 16:00 A → 2018-05-29 10:00 (+6d) |  | 100% → 0% | none → 8.29d | resources Project Manager → none; baseline start 2018-05-23 15:00 → 2011-04-20 10:30; baseline finish 2018-05-23 16:00 → 2011-04-20 11:30 |
| 29 | New PCs Arrive | 2018-06-01 16:00 A → 2018-06-04 14:00 (+3d) | 2018-06-01 17:00 A → 2018-06-04 15:00 (+3d) |  | 100% → 0% | none → 8.29d | resources Project Manager → none; baseline start 2018-06-01 16:00 → 2011-04-29 11:30; baseline finish 2018-06-01 17:00 → 2011-04-29 12:30 |
| 30 | Configure SOE on PCs | 2018-06-05 09:00 A → 2018-06-04 15:00 (-1d) | 2018-06-05 17:00 A → 2018-06-05 14:00 |  | 100% → 0% | none → 8.29d | resources IT Consultant → none; baseline start 2018-06-05 09:00 → 2011-04-29 12:30; baseline finish 2018-06-05 17:00 → 2011-05-03 12:30 |
| 31 | **Restructure Office** | 2018-05-23 09:00 A → 2018-05-28 09:00 (+5d) | 2018-06-18 09:00 A → 2018-06-12 13:30 (-6d) | 18d → 13.07d | 100% → 0% | none → 8.29d | baseline start 2018-05-23 09:00 → 2011-04-20 06:00; baseline finish 2018-06-18 09:00 → 2011-05-11 17:00 |
| 32 | Erect New Walls | 2018-05-23 09:00 A → 2018-05-28 09:00 (+5d) | 2018-05-26 08:00 A → 2018-05-28 17:00 (+2d) |  | 100% → 0% | none → 11.57d | resources Carpenter [200%] → none; baseline start 2018-05-23 09:00 → 2011-04-20 06:00; baseline finish 2018-05-26 08:00 → 2011-04-26 07:00 |
| 33 | Gyprock, Plaster & Finish | 2018-05-29 09:00 A → 2018-05-29 08:00 | 2018-06-02 13:00 A → 2018-05-30 15:00 (-3d) |  | 100% → 0% | none → 11.57d | resources Plasterer → none; baseline start 2018-05-29 09:00 → 2011-04-26 07:00; baseline finish 2018-06-02 13:00 → 2011-04-30 10:00 |
| 34 | Install Network Points | 2018-06-06 09:00 A → 2018-06-05 14:00 (-1d) | 2018-06-06 15:00 A → 2018-06-06 10:00 |  | 100% → 0% | none → 8.29d | resources IT Consultant → none; baseline start 2018-06-06 09:00 → 2011-05-03 12:30; baseline finish 2018-06-06 15:00 → 2011-05-04 10:30 |
| 35 | Install Phone Connections | 2018-06-06 09:00 A → 2018-06-05 14:00 (-1d) | 2018-06-06 12:30 A → 2018-06-06 08:30 |  | 100% → 0% | none → 8.29d | resources Telecommunications consultant → none; baseline start 2018-06-06 09:00 → 2011-05-03 12:30; baseline finish 2018-06-06 12:30 → 2011-05-03 17:00 |
| 36 | Re-Paint | 2018-06-07 09:00 A → 2018-06-06 08:30 (-1d) | 2018-06-09 11:00 A → 2018-06-06 16:30 (-3d) |  | 100% → 0% | none → 8.29d | resources Paint [100 Litre]; Painter → none; baseline start 2018-06-07 09:00 → 2011-05-04 06:00; baseline finish 2018-06-09 11:00 → 2011-05-06 07:00 |
| 37 | Carpet | 2018-06-11 09:00 A → 2018-06-07 16:30 (-4d) | 2018-06-14 07:00 A → 2018-06-08 15:30 (-6d) |  | 100% → 0% | none → 8.29d | resources Carpet [100 Lin Metre]; Carpet Contractor → none; baseline start 2018-06-11 09:00 → 2011-05-07 07:00; baseline finish 2018-06-14 07:00 → 2011-05-07 15:00 |
| 38 | Install New Furniture | 2018-06-13 09:00 A → 2018-06-08 15:30 (-5d) | 2018-06-16 08:00 A → 2018-06-11 14:30 (-5d) |  | 100% → 0% | none → 8.29d | resources Labourer → none; baseline start 2018-06-13 09:00 → 2011-05-09 06:00; baseline finish 2018-06-16 08:00 → 2011-05-11 07:00 |
| 39 | Install New PCs | 2018-06-15 09:00 A → 2018-06-11 14:30 (-4d) | 2018-06-15 17:00 A → 2018-06-12 13:30 (-3d) |  | 100% → 0% | none → 8.29d | resources IT Consultant → none; baseline start 2018-06-15 09:00 → 2011-05-11 09:00; baseline finish 2018-06-15 17:00 → 2011-05-11 17:00 |
| 40 | Refit Office Complete | 2018-06-18 09:00 A → 2018-06-12 13:30 (-6d) | 2018-06-18 09:00 A → 2018-06-12 13:30 (-6d) |  | 100% → 0% | none → 8.29d | baseline start 2018-06-18 09:00 → 2011-05-11 17:00; baseline finish 2018-06-18 09:00 → 2011-05-11 17:00 |
| 41 | **Office Move** | 2018-06-04 09:00 → 2018-06-04 15:00 | 2018-06-21 07:00 → 2018-06-26 08:00 (+5d) | 13d → 17.43d |  |  | baseline start 2018-06-04 09:00 → 2011-04-29 12:30; baseline finish 2018-06-21 07:00 → 2011-05-16 17:00 |
| 42 | Order packing boxes | 2018-06-04 09:00 → 2018-06-04 15:00 | 2018-06-04 10:00 → 2018-06-04 16:00 |  |  | 10.36d → 14.79d | resources Project Manager → none; baseline start 2018-06-04 09:00 → 2011-04-29 12:30; baseline finish 2018-06-04 10:00 → 2011-04-29 14:30 |
| 43 | Staff Pack | 2018-06-18 09:00 → 2018-06-12 13:30 (-6d) | 2018-06-18 12:30 → 2018-06-12 17:00 (-6d) |  |  | 0.5d → 8.29d | resources Project Manager; Staff [2000%] → none; baseline start 2018-06-18 09:00 → 2011-05-12 09:00; baseline finish 2018-06-18 12:30 → 2011-05-12 12:30 |
| 44 | Staff Move | 2018-06-18 12:30 → 2018-06-13 08:00 (-5d) | 2018-06-21 07:00 → 2018-06-14 15:00 (-7d) |  |  | 0d → 8.29d | resources Staff [2000%]; Labourer → none; baseline start 2018-06-18 12:30 → 2011-05-12 12:30; baseline finish 2018-06-21 07:00 → 2011-05-14 11:00 |
| 45 | Office Move Complete | 2018-06-21 07:00 → 2018-06-26 08:00 (+5d) | 2018-06-21 07:00 → 2018-06-26 08:00 (+5d) |  |  |  | constraint finish no later than 2018-06-22 19:00 → must finish on 2018-06-26 08:00; baseline start 2018-06-21 07:00 → 2011-05-16 17:00; baseline finish 2018-06-21 07:00 → 2011-05-16 17:00 |

## Version 10 (saved 2018-01-08, file Sharing Resources 1.mpp)

Last finish 2018-06-26 → 2018-06-19 (-7d).

Changed:

| ID | Task | Start | Finish | Other |
| --- | --- | --- | --- | --- |
| 1 | **Planning & Research** | 2018-05-14 08:00 → 2018-05-07 08:00 (-7d) | 2018-05-23 11:00 → 2018-05-16 11:00 (-7d) |  |
| 2 | Develop Requirements Documentation | 2018-05-14 08:00 → 2018-05-07 08:00 (-7d) | 2018-05-14 16:00 → 2018-05-07 16:00 (-7d) |  |
| 3 | Fit-Out Consultant Research | 2018-05-14 16:00 → 2018-05-07 16:00 (-7d) | 2018-05-15 10:30 → 2018-05-08 10:30 (-7d) |  |
| 4 | Telecommunications Consultant Research | 2018-05-15 10:30 → 2018-05-08 10:30 (-7d) | 2018-05-15 15:00 → 2018-05-08 15:00 (-7d) |  |
| 5 | IT Network Contractor Research | 2018-05-15 15:00 → 2018-05-08 15:00 (-7d) | 2018-05-16 09:30 → 2018-05-09 09:30 (-7d) |  |
| 6 | Building Contractors Research | 2018-05-16 09:30 → 2018-05-09 09:30 (-7d) | 2018-05-16 14:00 → 2018-05-09 14:00 (-7d) |  |
| 7 | Submit Requirements to Resources & Request Quotes | 2018-05-16 14:00 → 2018-05-09 14:00 (-7d) | 2018-05-16 16:00 → 2018-05-09 16:00 (-7d) |  |
| 8 | Quotes Received | 2018-05-23 10:00 → 2018-05-16 10:00 (-7d) | 2018-05-23 11:00 → 2018-05-16 11:00 (-7d) |  |
| 9 | Planning & Research Complete | 2018-05-23 11:00 → 2018-05-16 11:00 (-7d) | 2018-05-23 11:00 → 2018-05-16 11:00 (-7d) |  |
| 10 | **Management Approval** | 2018-05-23 11:00 → 2018-05-16 11:00 (-7d) | 2018-05-24 16:30 → 2018-05-17 16:30 (-7d) |  |
| 11 | Consolidate Quotes and develop proposal | 2018-05-23 11:00 → 2018-05-16 11:00 (-7d) | 2018-05-24 14:30 → 2018-05-17 14:30 (-7d) |  |
| 12 | Develop Project Plan & Durations | 2018-05-24 14:30 → 2018-05-17 14:30 (-7d) | 2018-05-24 15:30 → 2018-05-17 15:30 (-7d) |  |
| 13 | Submit Project Plan & Costs to Management | 2018-05-24 15:30 → 2018-05-17 15:30 (-7d) | 2018-05-24 16:30 → 2018-05-17 16:30 (-7d) |  |
| 14 | Management Approval Received | 2018-05-24 16:30 → 2018-05-17 16:30 (-7d) | 2018-05-24 16:30 → 2018-05-17 16:30 (-7d) |  |
| 15 | **Refit Office** | 2018-05-24 16:30 → 2018-05-17 16:30 (-7d) | 2018-06-12 13:30 → 2018-06-05 13:30 (-7d) |  |
| 16 | Appoint Resources | 2018-05-24 16:30 → 2018-05-17 16:30 (-7d) | 2018-05-25 09:30 → 2018-05-18 09:30 (-7d) |  |
| 17 | Staff Briefing | 2018-05-25 09:30 → 2018-05-18 09:30 (-7d) | 2018-05-25 10:30 → 2018-05-18 10:30 (-7d) |  |
| 18 | **Fit-Out Consultations** | 2018-05-25 10:30 → 2018-05-18 10:30 (-7d) | 2018-05-28 09:00 → 2018-05-21 09:00 (-7d) |  |
| 19 | Office Space / Structure Plan | 2018-05-25 10:30 → 2018-05-18 10:30 (-7d) | 2018-05-25 15:00 → 2018-05-18 15:00 (-7d) |  |
| 20 | Select & Order Carpet | 2018-05-25 15:00 → 2018-05-18 15:00 (-7d) | 2018-05-25 16:00 → 2018-05-18 16:00 (-7d) |  |
| 21 | Select & Order Paint | 2018-05-25 16:00 → 2018-05-18 16:00 (-7d) | 2018-05-25 17:00 → 2018-05-18 17:00 (-7d) |  |
| 22 | Select & Order Office Furniture | 2018-05-28 08:00 → 2018-05-21 08:00 (-7d) | 2018-05-28 09:00 → 2018-05-21 09:00 (-7d) |  |
| 23 | **Telecommuncations Consultations** | 2018-05-28 09:00 → 2018-05-21 09:00 (-7d) | 2018-05-28 14:30 → 2018-05-21 14:30 (-7d) |  |
| 24 | Design Telephone Access Points Map | 2018-05-28 09:00 → 2018-05-21 09:00 (-7d) | 2018-05-28 13:30 → 2018-05-21 13:30 (-7d) |  |
| 25 | Select & Order New PABX | 2018-05-28 13:30 → 2018-05-21 13:30 (-7d) | 2018-05-28 14:30 → 2018-05-21 14:30 (-7d) |  |
| 26 | **IT Networking Consultations** | 2018-05-28 14:30 → 2018-05-21 14:30 (-7d) | 2018-06-05 14:00 → 2018-05-29 14:00 (-7d) |  |
| 27 | Design Network Access Points Map | 2018-05-28 14:30 → 2018-05-21 14:30 (-7d) | 2018-05-29 09:00 → 2018-05-22 09:00 (-7d) |  |
| 28 | Select & Order New PCs | 2018-05-29 09:00 → 2018-05-22 09:00 (-7d) | 2018-05-29 10:00 → 2018-05-22 10:00 (-7d) |  |
| 29 | New PCs Arrive | 2018-06-04 14:00 → 2018-05-28 14:00 (-7d) | 2018-06-04 15:00 → 2018-05-28 15:00 (-7d) |  |
| 30 | Configure SOE on PCs | 2018-06-04 15:00 → 2018-05-28 15:00 (-7d) | 2018-06-05 14:00 → 2018-05-29 14:00 (-7d) |  |
| 31 | **Restructure Office** | 2018-05-28 09:00 → 2018-05-21 09:00 (-7d) | 2018-06-12 13:30 → 2018-06-05 13:30 (-7d) |  |
| 32 | Erect New Walls | 2018-05-28 09:00 → 2018-05-21 09:00 (-7d) | 2018-05-28 17:00 → 2018-05-21 17:00 (-7d) |  |
| 33 | Gyprock, Plaster & Finish | 2018-05-29 08:00 → 2018-05-22 08:00 (-7d) | 2018-05-30 15:00 → 2018-05-23 15:00 (-7d) |  |
| 34 | Install Network Points | 2018-06-05 14:00 → 2018-05-29 14:00 (-7d) | 2018-06-06 10:00 → 2018-05-30 10:00 (-7d) |  |
| 35 | Install Phone Connections | 2018-06-05 14:00 → 2018-05-29 14:00 (-7d) | 2018-06-06 08:30 → 2018-05-30 08:30 (-7d) |  |
| 36 | Re-Paint | 2018-06-06 08:30 → 2018-05-30 08:30 (-7d) | 2018-06-06 16:30 → 2018-05-30 16:30 (-7d) |  |
| 37 | Carpet | 2018-06-07 16:30 → 2018-05-31 16:30 (-7d) | 2018-06-08 15:30 → 2018-06-01 15:30 (-7d) |  |
| 38 | Install New Furniture | 2018-06-08 15:30 → 2018-06-01 15:30 (-7d) | 2018-06-11 14:30 → 2018-06-04 14:30 (-7d) |  |
| 39 | Install New PCs | 2018-06-11 14:30 → 2018-06-04 14:30 (-7d) | 2018-06-12 13:30 → 2018-06-05 13:30 (-7d) |  |
| 40 | Refit Office Complete | 2018-06-12 13:30 → 2018-06-05 13:30 (-7d) | 2018-06-12 13:30 → 2018-06-05 13:30 (-7d) |  |
| 41 | **Office Move** | 2018-06-04 15:00 → 2018-05-28 15:00 (-7d) | 2018-06-26 08:00 → 2018-06-19 08:00 (-7d) |  |
| 42 | Order packing boxes | 2018-06-04 15:00 → 2018-05-28 15:00 (-7d) | 2018-06-04 16:00 → 2018-05-28 16:00 (-7d) |  |
| 43 | Staff Pack | 2018-06-12 13:30 → 2018-06-05 13:30 (-7d) | 2018-06-12 17:00 → 2018-06-05 17:00 (-7d) |  |
| 44 | Staff Move | 2018-06-13 08:00 → 2018-06-06 08:00 (-7d) | 2018-06-14 15:00 → 2018-06-07 15:00 (-7d) |  |
| 45 | Office Move Complete | 2018-06-26 08:00 → 2018-06-19 08:00 (-7d) | 2018-06-26 08:00 → 2018-06-19 08:00 (-7d) | constraint must finish on 2018-06-26 08:00 → must finish on 2018-06-19 08:00 |

## Version 11 (saved 2018-01-08, file Tables.mpp)

Last finish 2018-06-19 → 2018-06-21 (+2d). Complete tasks 0 → 33.

Changed:

| ID | Task | Start | Finish | Duration | Complete | Total float | Other |
| --- | --- | --- | --- | --- | --- | --- | --- |
| 1 | **Planning & Research** | 2018-05-07 08:00 → 2018-05-07 09:00 A | 2018-05-16 11:00 → 2018-05-17 12:00 A (+1d) |  | 0% → 100% | 0.14d → none | baseline start 2011-04-04 09:00 → 2018-05-07 09:00; baseline finish 2011-04-14 12:00 → 2018-05-17 12:00 |
| 2 | Develop Requirements Documentation | 2018-05-07 08:00 → 2018-05-07 09:00 A | 2018-05-07 16:00 → 2018-05-07 17:00 A |  | 0% → 100% | 0.14d → none | resources none → Project Manager; baseline start 2011-04-04 09:00 → 2018-05-07 09:00; baseline finish 2011-04-04 17:00 → 2018-05-07 17:00 |
| 3 | Fit-Out Consultant Research | 2018-05-07 16:00 → 2018-05-08 09:00 A (+1d) | 2018-05-08 10:30 → 2018-05-08 12:30 A |  | 0% → 100% | 8.29d → none | resources none → Project Manager; baseline start 2011-04-05 09:00 → 2018-05-08 09:00; baseline finish 2011-04-05 12:30 → 2018-05-08 12:30 |
| 4 | Telecommunications Consultant Research | 2018-05-08 10:30 → 2018-05-08 12:30 A | 2018-05-08 15:00 → 2018-05-08 17:00 A |  | 0% → 100% | 8.29d → none | resources none → Project Manager; baseline start 2011-04-05 12:30 → 2018-05-08 12:30; baseline finish 2011-04-05 17:00 → 2018-05-08 17:00 |
| 5 | IT Network Contractor Research | 2018-05-08 15:00 → 2018-05-09 09:00 A (+1d) | 2018-05-09 09:30 → 2018-05-09 12:30 A |  | 0% → 100% | 8.29d → none | resources none → Project Manager; baseline start 2011-04-06 09:00 → 2018-05-09 09:00; baseline finish 2011-04-06 12:30 → 2018-05-09 12:30 |
| 6 | Building Contractors Research | 2018-05-09 09:30 → 2018-05-09 12:30 A | 2018-05-09 14:00 → 2018-05-09 17:00 A |  | 0% → 100% | 8.29d → none | resources none → Project Manager; baseline start 2011-04-06 12:30 → 2018-05-09 12:30; baseline finish 2011-04-06 17:00 → 2018-05-09 17:00 |
| 7 | Submit Requirements to Resources & Request Quotes | 2018-05-09 14:00 → 2018-05-10 09:00 A (+1d) | 2018-05-09 16:00 → 2018-05-10 11:00 A (+1d) |  | 0% → 100% | 8.29d → none | resources none → Project Manager; baseline start 2011-04-07 09:00 → 2018-05-10 09:00; baseline finish 2011-04-07 11:00 → 2018-05-10 11:00 |
| 8 | Quotes Received | 2018-05-16 10:00 → 2018-05-17 11:00 A (+1d) | 2018-05-16 11:00 → 2018-05-17 12:00 A (+1d) |  | 0% → 100% | 8.29d → none | resources none → Project Manager; baseline start 2011-04-14 11:00 → 2018-05-17 11:00; baseline finish 2011-04-14 12:00 → 2018-05-17 12:00 |
| 9 | Planning & Research Complete | 2018-05-16 11:00 → 2018-05-17 12:00 A (+1d) | 2018-05-16 11:00 → 2018-05-17 12:00 A (+1d) |  | 0% → 100% | 8.29d → none | baseline start 2011-04-14 12:00 → 2018-05-17 12:00; baseline finish 2011-04-14 12:00 → 2018-05-17 12:00 |
| 10 | **Management Approval** | 2018-05-16 11:00 → 2018-05-17 12:00 A (+1d) | 2018-05-17 16:30 → 2018-05-21 10:30 A (+4d) |  | 0% → 100% | 8.29d → none | baseline start 2011-04-14 12:00 → 2018-05-17 12:00; baseline finish 2011-04-15 15:00 → 2018-05-21 10:30 |
| 11 | Consolidate Quotes and develop proposal | 2018-05-16 11:00 → 2018-05-17 12:00 A (+1d) | 2018-05-17 14:30 → 2018-05-18 16:30 A (+1d) |  | 0% → 100% | 8.29d → none | resources none → Project Manager; baseline start 2011-04-14 12:00 → 2018-05-17 12:00; baseline finish 2011-04-15 12:00 → 2018-05-18 16:30 |
| 12 | Develop Project Plan & Durations | 2018-05-17 14:30 → 2018-05-18 16:30 A (+1d) | 2018-05-17 15:30 → 2018-05-21 09:30 A (+4d) |  | 0% → 100% | 8.29d → none | resources none → Project Manager; baseline start 2011-04-15 12:00 → 2018-05-18 16:30; baseline finish 2011-04-15 13:00 → 2018-05-21 09:30 |
| 13 | Submit Project Plan & Costs to Management | 2018-05-17 15:30 → 2018-05-21 09:30 A (+4d) | 2018-05-17 16:30 → 2018-05-21 10:30 A (+4d) |  | 0% → 100% | 8.29d → none | resources none → Project Manager; Management; baseline start 2011-04-15 14:00 → 2018-05-21 09:30; baseline finish 2011-04-15 15:00 → 2018-05-21 10:30 |
| 14 | Management Approval Received | 2018-05-17 16:30 → 2018-05-21 10:30 A (+4d) | 2018-05-17 16:30 → 2018-05-21 10:30 A (+4d) |  | 0% → 100% | 8.29d → none | baseline start 2011-04-15 15:00 → 2018-05-21 10:30; baseline finish 2011-04-15 15:00 → 2018-05-21 10:30 |
| 15 | **Refit Office** | 2018-05-17 16:30 → 2018-05-21 10:30 A (+4d) | 2018-06-05 13:30 → 2018-06-18 09:00 A (+13d) | 14.43d → 19.79d | 0% → 100% | 8.29d → none | baseline start 2011-04-15 15:00 → 2018-05-21 10:30; baseline finish 2011-05-11 17:00 → 2018-06-18 09:00 |
| 16 | Appoint Resources | 2018-05-17 16:30 → 2018-05-21 10:30 A (+4d) | 2018-05-18 09:30 → 2018-05-21 12:30 A (+3d) |  | 0% → 100% | 8.29d → none | resources none → Project Manager; baseline start 2011-04-15 15:00 → 2018-05-21 10:30; baseline finish 2011-04-15 17:00 → 2018-05-21 12:30 |
| 17 | Staff Briefing | 2018-05-18 09:30 → 2018-05-21 12:30 A (+3d) | 2018-05-18 10:30 → 2018-05-21 14:30 A (+3d) |  | 0% → 100% | 8.29d → none | resources none → Project Manager; Staff [700%]; baseline start 2011-04-18 09:00 → 2018-05-21 12:30; baseline finish 2011-04-18 10:00 → 2018-05-21 14:30 |
| 18 | **Fit-Out Consultations** | 2018-05-18 10:30 → 2018-05-21 14:30 A (+3d) | 2018-05-21 09:00 → 2018-05-22 13:00 A (+1d) |  | 0% → 100% | 8.29d → none | baseline start 2011-04-18 10:00 → 2018-05-21 14:30; baseline finish 2011-04-19 09:30 → 2018-05-22 13:00 |
| 19 | Office Space / Structure Plan | 2018-05-18 10:30 → 2018-05-21 14:30 A (+3d) | 2018-05-18 15:00 → 2018-05-22 10:00 A (+4d) |  | 0% → 100% | 8.29d → none | resources none → Fit-out Consultant; Project Manager; baseline start 2011-04-18 10:00 → 2018-05-21 14:30; baseline finish 2011-04-18 14:30 → 2018-05-22 10:00 |
| 20 | Select & Order Carpet | 2018-05-18 15:00 → 2018-05-22 10:00 A (+4d) | 2018-05-18 16:00 → 2018-05-22 11:00 A (+4d) |  | 0% → 100% | 8.29d → none | resources none → Fit-out Consultant; Project Manager; baseline start 2011-04-18 14:30 → 2018-05-22 10:00; baseline finish 2011-04-18 15:30 → 2018-05-22 11:00 |
| 21 | Select & Order Paint | 2018-05-18 16:00 → 2018-05-22 11:00 A (+4d) | 2018-05-18 17:00 → 2018-05-22 12:00 A (+4d) |  | 0% → 100% | 8.29d → none | resources none → Fit-out Consultant; Project Manager; baseline start 2011-04-18 15:30 → 2018-05-22 11:00; baseline finish 2011-04-18 16:30 → 2018-05-22 12:00 |
| 22 | Select & Order Office Furniture | 2018-05-21 08:00 → 2018-05-22 12:00 A (+1d) | 2018-05-21 09:00 → 2018-05-22 13:00 A (+1d) |  | 0% → 100% | 8.29d → none | resources none → Fit-out Consultant; Project Manager; baseline start 2011-04-18 16:30 → 2018-05-22 12:00; baseline finish 2011-04-19 09:30 → 2018-05-22 13:00 |
| 23 | **Telecommuncations Consultations** | 2018-05-21 09:00 → 2018-05-22 14:00 A (+1d) | 2018-05-21 14:30 → 2018-05-23 10:30 A (+2d) |  | 0% → 100% | 8.29d → none | baseline start 2011-04-19 09:30 → 2018-05-22 14:00; baseline finish 2011-04-19 15:00 → 2018-05-23 10:30 |
| 24 | Design Telephone Access Points Map | 2018-05-21 09:00 → 2018-05-22 14:00 A (+1d) | 2018-05-21 13:30 → 2018-05-23 09:30 A (+2d) |  | 0% → 100% | 8.29d → none | resources none → Project Manager; Telecommunications consultant; baseline start 2011-04-19 09:30 → 2018-05-22 14:00; baseline finish 2011-04-19 13:00 → 2018-05-23 09:30 |
| 25 | Select & Order New PABX | 2018-05-21 13:30 → 2018-05-23 09:30 A (+2d) | 2018-05-21 14:30 → 2018-05-23 10:30 A (+2d) |  | 0% → 100% | 8.29d → none | resources none → Project Manager; baseline start 2011-04-19 14:00 → 2018-05-23 09:30; baseline finish 2011-04-19 15:00 → 2018-05-23 10:30 |
| 26 | **IT Networking Consultations** | 2018-05-21 14:30 → 2018-05-23 10:30 A (+2d) | 2018-05-29 14:00 → 2018-06-05 17:00 A (+7d) | 6.79d → 9.79d | 0% → 100% | 8.29d → none | baseline start 2011-04-19 15:00 → 2018-05-23 10:30; baseline finish 2011-05-03 12:30 → 2018-06-05 17:00 |
| 27 | Design Network Access Points Map | 2018-05-21 14:30 → 2018-05-23 10:30 A (+2d) | 2018-05-22 09:00 → 2018-05-23 15:00 A (+1d) |  | 0% → 100% | 8.29d → none | resources none → IT Consultant; Project Manager; baseline start 2011-04-19 15:00 → 2018-05-23 10:30; baseline finish 2011-04-20 10:30 → 2018-05-23 15:00 |
| 28 | Select & Order New PCs | 2018-05-22 09:00 → 2018-05-23 15:00 A (+1d) | 2018-05-22 10:00 → 2018-05-23 16:00 A (+1d) |  | 0% → 100% | 8.29d → none | resources none → Project Manager; baseline start 2011-04-20 10:30 → 2018-05-23 15:00; baseline finish 2011-04-20 11:30 → 2018-05-23 16:00 |
| 29 | New PCs Arrive | 2018-05-28 14:00 → 2018-06-01 16:00 A (+4d) | 2018-05-28 15:00 → 2018-06-01 17:00 A (+4d) |  | 0% → 100% | 8.29d → none | resources none → Project Manager; baseline start 2011-04-29 11:30 → 2018-06-01 16:00; baseline finish 2011-04-29 12:30 → 2018-06-01 17:00 |
| 30 | Configure SOE on PCs | 2018-05-28 15:00 → 2018-06-05 09:00 A (+8d) | 2018-05-29 14:00 → 2018-06-05 17:00 A (+7d) |  | 0% → 100% | 8.29d → none | resources none → IT Consultant; baseline start 2011-04-29 12:30 → 2018-06-05 09:00; baseline finish 2011-05-03 12:30 → 2018-06-05 17:00 |
| 31 | **Restructure Office** | 2018-05-21 09:00 → 2018-05-23 09:00 A (+2d) | 2018-06-05 13:30 → 2018-06-18 09:00 A (+13d) | 13.07d → 18d | 0% → 100% | 8.29d → none | baseline start 2011-04-20 06:00 → 2018-05-23 09:00; baseline finish 2011-05-11 17:00 → 2018-06-18 09:00 |
| 32 | Erect New Walls | 2018-05-21 09:00 → 2018-05-23 09:00 A (+2d) | 2018-05-21 17:00 → 2018-05-26 08:00 A (+5d) |  | 0% → 100% | 11.57d → none | resources none → Carpenter [200%]; baseline start 2011-04-20 06:00 → 2018-05-23 09:00; baseline finish 2011-04-26 07:00 → 2018-05-26 08:00 |
| 33 | Gyprock, Plaster & Finish | 2018-05-22 08:00 → 2018-05-29 09:00 A (+7d) | 2018-05-23 15:00 → 2018-06-02 13:00 A (+10d) |  | 0% → 100% | 11.57d → none | resources none → Plasterer; baseline start 2011-04-26 07:00 → 2018-05-29 09:00; baseline finish 2011-04-30 10:00 → 2018-06-02 13:00 |
| 34 | Install Network Points | 2018-05-29 14:00 → 2018-06-06 09:00 A (+8d) | 2018-05-30 10:00 → 2018-06-06 15:00 A (+7d) |  | 0% → 100% | 8.29d → none | resources none → IT Consultant; baseline start 2011-05-03 12:30 → 2018-06-06 09:00; baseline finish 2011-05-04 10:30 → 2018-06-06 15:00 |
| 35 | Install Phone Connections | 2018-05-29 14:00 → 2018-06-06 09:00 A (+8d) | 2018-05-30 08:30 → 2018-06-06 12:30 A (+7d) |  | 0% → 100% | 8.29d → none | resources none → Telecommunications consultant; baseline start 2011-05-03 12:30 → 2018-06-06 09:00; baseline finish 2011-05-03 17:00 → 2018-06-06 12:30 |
| 36 | Re-Paint | 2018-05-30 08:30 → 2018-06-07 09:00 A (+8d) | 2018-05-30 16:30 → 2018-06-09 11:00 A (+10d) |  | 0% → 100% | 8.29d → none | resources none → Paint [100 Litre]; Painter; baseline start 2011-05-04 06:00 → 2018-06-07 09:00; baseline finish 2011-05-06 07:00 → 2018-06-09 11:00 |
| 37 | Carpet | 2018-05-31 16:30 → 2018-06-11 09:00 A (+11d) | 2018-06-01 15:30 → 2018-06-14 07:00 A (+13d) |  | 0% → 100% | 8.29d → none | resources none → Carpet [100 Lin Metre]; Carpet Contractor; baseline start 2011-05-07 07:00 → 2018-06-11 09:00; baseline finish 2011-05-07 15:00 → 2018-06-14 07:00 |
| 38 | Install New Furniture | 2018-06-01 15:30 → 2018-06-13 09:00 A (+12d) | 2018-06-04 14:30 → 2018-06-16 08:00 A (+12d) |  | 0% → 100% | 8.29d → none | resources none → Labourer; baseline start 2011-05-09 06:00 → 2018-06-13 09:00; baseline finish 2011-05-11 07:00 → 2018-06-16 08:00 |
| 39 | Install New PCs | 2018-06-04 14:30 → 2018-06-15 09:00 A (+11d) | 2018-06-05 13:30 → 2018-06-15 17:00 A (+10d) |  | 0% → 100% | 8.29d → none | resources none → IT Consultant; baseline start 2011-05-11 09:00 → 2018-06-15 09:00; baseline finish 2011-05-11 17:00 → 2018-06-15 17:00 |
| 40 | Refit Office Complete | 2018-06-05 13:30 → 2018-06-18 09:00 A (+13d) | 2018-06-05 13:30 → 2018-06-18 09:00 A (+13d) |  | 0% → 100% | 8.29d → none | baseline start 2011-05-11 17:00 → 2018-06-18 09:00; baseline finish 2011-05-11 17:00 → 2018-06-18 09:00 |
| 41 | **Office Move** | 2018-05-28 15:00 → 2018-06-04 09:00 (+7d) | 2018-06-19 08:00 → 2018-06-21 07:00 (+2d) | 17.43d → 13d |  |  | baseline start 2011-04-29 12:30 → 2018-06-04 09:00; baseline finish 2011-05-16 17:00 → 2018-06-21 07:00 |
| 42 | Order packing boxes | 2018-05-28 15:00 → 2018-06-04 09:00 (+7d) | 2018-05-28 16:00 → 2018-06-04 10:00 (+7d) |  |  | 14.79d → 10.36d | resources none → Project Manager; baseline start 2011-04-29 12:30 → 2018-06-04 09:00; baseline finish 2011-04-29 14:30 → 2018-06-04 10:00 |
| 43 | Staff Pack | 2018-06-05 13:30 → 2018-06-18 09:00 (+13d) | 2018-06-05 17:00 → 2018-06-18 12:30 (+13d) |  |  | 8.29d → 0.5d | resources none → Project Manager; Staff [2000%]; baseline start 2011-05-12 09:00 → 2018-06-18 09:00; baseline finish 2011-05-12 12:30 → 2018-06-18 12:30 |
| 44 | Staff Move | 2018-06-06 08:00 → 2018-06-18 12:30 (+12d) | 2018-06-07 15:00 → 2018-06-21 07:00 (+14d) |  |  | 8.29d → 0d | resources none → Staff [2000%]; Labourer; baseline start 2011-05-12 12:30 → 2018-06-18 12:30; baseline finish 2011-05-14 11:00 → 2018-06-21 07:00 |
| 45 | Office Move Complete | 2018-06-19 08:00 → 2018-06-21 07:00 (+2d) | 2018-06-19 08:00 → 2018-06-21 07:00 (+2d) |  |  |  | constraint must finish on 2018-06-19 08:00 → finish no later than 2018-06-22 19:00; baseline start 2011-05-16 17:00 → 2018-06-21 07:00; baseline finish 2011-05-16 17:00 → 2018-06-21 07:00 |

## Version 12 (saved 2018-01-08, file WBS.mpp)

Last finish 2018-06-21 → 2018-06-14 (-7d). Complete tasks 33 → 0.

Changed:

| ID | Task | Start | Finish | Duration | Complete | Total float | Other |
| --- | --- | --- | --- | --- | --- | --- | --- |
| 1 | **Planning & Research** | 2018-05-07 09:00 A → 2018-05-07 09:00 | 2018-05-17 12:00 A → 2018-05-17 12:00 |  | 100% → 0% | none → 0d | baseline start 2018-05-07 09:00 → 2011-04-04 09:00; baseline finish 2018-05-17 12:00 → 2011-04-14 12:00 |
| 2 | Develop Requirements Documentation | 2018-05-07 09:00 A → 2018-05-07 09:00 | 2018-05-07 17:00 A → 2018-05-07 17:00 |  | 100% → 0% | none → 0d | baseline start 2018-05-07 09:00 → 2011-04-04 09:00; baseline finish 2018-05-07 17:00 → 2011-04-04 17:00 |
| 3 | Fit-Out Consultant Research | 2018-05-08 09:00 A → 2018-05-08 09:00 | 2018-05-08 12:30 A → 2018-05-08 12:30 |  | 100% → 0% | none → 0.5d | baseline start 2018-05-08 09:00 → 2011-04-05 09:00; baseline finish 2018-05-08 12:30 → 2011-04-05 12:30 |
| 4 | Telecommunications Consultant Research | 2018-05-08 12:30 A → 2018-05-08 12:30 | 2018-05-08 17:00 A → 2018-05-08 17:00 |  | 100% → 0% | none → 0.5d | baseline start 2018-05-08 12:30 → 2011-04-05 12:30; baseline finish 2018-05-08 17:00 → 2011-04-05 17:00 |
| 5 | IT Network Contractor Research | 2018-05-09 09:00 A → 2018-05-09 09:00 | 2018-05-09 12:30 A → 2018-05-09 12:30 |  | 100% → 0% | none → 0.5d | baseline start 2018-05-09 09:00 → 2011-04-06 09:00; baseline finish 2018-05-09 12:30 → 2011-04-06 12:30 |
| 6 | Building Contractors Research | 2018-05-09 12:30 A → 2018-05-09 12:30 | 2018-05-09 17:00 A → 2018-05-09 17:00 |  | 100% → 0% | none → 0.5d | baseline start 2018-05-09 12:30 → 2011-04-06 12:30; baseline finish 2018-05-09 17:00 → 2011-04-06 17:00 |
| 7 | Submit Requirements to Resources & Request Quotes | 2018-05-10 09:00 A → 2018-05-10 09:00 | 2018-05-10 11:00 A → 2018-05-10 11:00 |  | 100% → 0% | none → 0.5d | baseline start 2018-05-10 09:00 → 2011-04-07 09:00; baseline finish 2018-05-10 11:00 → 2011-04-07 11:00 |
| 8 | Quotes Received | 2018-05-17 11:00 A → 2018-05-17 11:00 | 2018-05-17 12:00 A → 2018-05-17 12:00 |  | 100% → 0% | none → 0.5d | baseline start 2018-05-17 11:00 → 2011-04-14 11:00; baseline finish 2018-05-17 12:00 → 2011-04-14 12:00 |
| 9 | Planning & Research Complete | 2018-05-17 12:00 A → 2018-05-17 12:00 | 2018-05-17 12:00 A → 2018-05-17 12:00 |  | 100% → 0% | none → 0.5d | baseline start 2018-05-17 12:00 → 2011-04-14 12:00; baseline finish 2018-05-17 12:00 → 2011-04-14 12:00 |
| 10 | **Management Approval** | 2018-05-17 12:00 A → 2018-05-17 12:00 | 2018-05-21 10:30 A → 2018-05-21 10:30 |  | 100% → 0% | none → 0.5d | baseline start 2018-05-17 12:00 → 2011-04-14 12:00; baseline finish 2018-05-21 10:30 → 2011-04-15 15:00 |
| 11 | Consolidate Quotes and develop proposal | 2018-05-17 12:00 A → 2018-05-17 12:00 | 2018-05-18 16:30 A → 2018-05-18 16:30 |  | 100% → 0% | none → 0.5d | baseline start 2018-05-17 12:00 → 2011-04-14 12:00; baseline finish 2018-05-18 16:30 → 2011-04-15 12:00 |
| 12 | Develop Project Plan & Durations | 2018-05-18 16:30 A → 2018-05-18 16:30 | 2018-05-21 09:30 A → 2018-05-21 09:30 |  | 100% → 0% | none → 0.5d | baseline start 2018-05-18 16:30 → 2011-04-15 12:00; baseline finish 2018-05-21 09:30 → 2011-04-15 13:00 |
| 13 | Submit Project Plan & Costs to Management | 2018-05-21 09:30 A → 2018-05-21 09:30 | 2018-05-21 10:30 A → 2018-05-21 10:30 |  | 100% → 0% | none → 0.5d | baseline start 2018-05-21 09:30 → 2011-04-15 14:00; baseline finish 2018-05-21 10:30 → 2011-04-15 15:00 |
| 14 | Management Approval Received | 2018-05-21 10:30 A → 2018-05-21 10:30 | 2018-05-21 10:30 A → 2018-05-21 10:30 |  | 100% → 0% | none → 0.5d | baseline start 2018-05-21 10:30 → 2011-04-15 15:00; baseline finish 2018-05-21 10:30 → 2011-04-15 15:00 |
| 15 | **Refit Office** | 2018-05-21 10:30 A → 2018-05-21 10:30 | 2018-06-18 09:00 A → 2018-06-08 17:00 (-10d) | 19.79d → 14.79d | 100% → 0% | none → 0.5d | baseline start 2018-05-21 10:30 → 2011-04-15 15:00; baseline finish 2018-06-18 09:00 → 2011-05-11 17:00 |
| 16 | Appoint Resources | 2018-05-21 10:30 A → 2018-05-21 10:30 | 2018-05-21 12:30 A → 2018-05-21 12:30 |  | 100% → 0% | none → 0.5d | baseline start 2018-05-21 10:30 → 2011-04-15 15:00; baseline finish 2018-05-21 12:30 → 2011-04-15 17:00 |
| 17 | Staff Briefing | 2018-05-21 12:30 A → 2018-05-21 12:30 | 2018-05-21 14:30 A → 2018-05-21 14:30 |  | 100% → 0% | none → 0.5d | baseline start 2018-05-21 12:30 → 2011-04-18 09:00; baseline finish 2018-05-21 14:30 → 2011-04-18 10:00 |
| 18 | **Fit-Out Consultations** | 2018-05-21 14:30 A → 2018-05-21 14:30 | 2018-05-22 13:00 A → 2018-05-22 13:00 |  | 100% → 0% | none → 0.5d | baseline start 2018-05-21 14:30 → 2011-04-18 10:00; baseline finish 2018-05-22 13:00 → 2011-04-19 09:30 |
| 19 | Office Space / Structure Plan | 2018-05-21 14:30 A → 2018-05-21 14:30 | 2018-05-22 10:00 A → 2018-05-22 10:00 |  | 100% → 0% | none → 0.5d | baseline start 2018-05-21 14:30 → 2011-04-18 10:00; baseline finish 2018-05-22 10:00 → 2011-04-18 14:30 |
| 20 | Select & Order Carpet | 2018-05-22 10:00 A → 2018-05-22 10:00 | 2018-05-22 11:00 A → 2018-05-22 11:00 |  | 100% → 0% | none → 0.5d | baseline start 2018-05-22 10:00 → 2011-04-18 14:30; baseline finish 2018-05-22 11:00 → 2011-04-18 15:30 |
| 21 | Select & Order Paint | 2018-05-22 11:00 A → 2018-05-22 11:00 | 2018-05-22 12:00 A → 2018-05-22 12:00 |  | 100% → 0% | none → 0.5d | baseline start 2018-05-22 11:00 → 2011-04-18 15:30; baseline finish 2018-05-22 12:00 → 2011-04-18 16:30 |
| 22 | Select & Order Office Furniture | 2018-05-22 12:00 A → 2018-05-22 12:00 | 2018-05-22 13:00 A → 2018-05-22 13:00 |  | 100% → 0% | none → 0.5d | baseline start 2018-05-22 12:00 → 2011-04-18 16:30; baseline finish 2018-05-22 13:00 → 2011-04-19 09:30 |
| 23 | **Telecommuncations Consultations** | 2018-05-22 14:00 A → 2018-05-22 14:00 | 2018-05-23 10:30 A → 2018-05-23 10:30 |  | 100% → 0% | none → 0.5d | baseline start 2018-05-22 14:00 → 2011-04-19 09:30; baseline finish 2018-05-23 10:30 → 2011-04-19 15:00 |
| 24 | Design Telephone Access Points Map | 2018-05-22 14:00 A → 2018-05-22 14:00 | 2018-05-23 09:30 A → 2018-05-23 09:30 |  | 100% → 0% | none → 0.5d | baseline start 2018-05-22 14:00 → 2011-04-19 09:30; baseline finish 2018-05-23 09:30 → 2011-04-19 13:00 |
| 25 | Select & Order New PABX | 2018-05-23 09:30 A → 2018-05-23 09:30 | 2018-05-23 10:30 A → 2018-05-23 10:30 |  | 100% → 0% | none → 0.5d | baseline start 2018-05-23 09:30 → 2011-04-19 14:00; baseline finish 2018-05-23 10:30 → 2011-04-19 15:00 |
| 26 | **IT Networking Consultations** | 2018-05-23 10:30 A → 2018-05-23 10:30 | 2018-06-05 17:00 A → 2018-05-31 17:00 (-5d) | 9.79d → 6.79d | 100% → 0% | none → 0.5d | baseline start 2018-05-23 10:30 → 2011-04-19 15:00; baseline finish 2018-06-05 17:00 → 2011-05-03 12:30 |
| 27 | Design Network Access Points Map | 2018-05-23 10:30 A → 2018-05-23 10:30 | 2018-05-23 15:00 A → 2018-05-23 15:00 |  | 100% → 0% | none → 0.5d | baseline start 2018-05-23 10:30 → 2011-04-19 15:00; baseline finish 2018-05-23 15:00 → 2011-04-20 10:30 |
| 28 | Select & Order New PCs | 2018-05-23 15:00 A → 2018-05-23 15:00 | 2018-05-23 16:00 A → 2018-05-23 16:00 |  | 100% → 0% | none → 0.5d | baseline start 2018-05-23 15:00 → 2011-04-20 10:30; baseline finish 2018-05-23 16:00 → 2011-04-20 11:30 |
| 29 | New PCs Arrive | 2018-06-01 16:00 A → 2018-05-30 16:00 (-2d) | 2018-06-01 17:00 A → 2018-05-30 17:00 (-2d) |  | 100% → 0% | none → 0.5d | baseline start 2018-06-01 16:00 → 2011-04-29 11:30; baseline finish 2018-06-01 17:00 → 2011-04-29 12:30 |
| 30 | Configure SOE on PCs | 2018-06-05 09:00 A → 2018-05-31 09:00 (-5d) | 2018-06-05 17:00 A → 2018-05-31 17:00 (-5d) |  | 100% → 0% | none → 0.5d | baseline start 2018-06-05 09:00 → 2011-04-29 12:30; baseline finish 2018-06-05 17:00 → 2011-05-03 12:30 |
| 31 | **Restructure Office** | 2018-05-23 09:00 A → 2018-05-23 06:00 | 2018-06-18 09:00 A → 2018-06-08 17:00 (-10d) | 18d → 13d | 100% → 0% | none → 0.5d | baseline start 2018-05-23 09:00 → 2011-04-20 06:00; baseline finish 2018-06-18 09:00 → 2011-05-11 17:00 |
| 32 | Erect New Walls | 2018-05-23 09:00 A → 2018-05-23 06:00 | 2018-05-26 08:00 A → 2018-05-25 07:00 (-1d) |  | 100% → 0% | none → 1d | baseline start 2018-05-23 09:00 → 2011-04-20 06:00; baseline finish 2018-05-26 08:00 → 2011-04-26 07:00 |
| 33 | Gyprock, Plaster & Finish | 2018-05-29 09:00 A → 2018-05-25 07:00 (-4d) | 2018-06-02 13:00 A → 2018-05-29 08:00 (-4d) |  | 100% → 0% | none → 1d | baseline start 2018-05-29 09:00 → 2011-04-26 07:00; baseline finish 2018-06-02 13:00 → 2011-04-30 10:00 |
| 34 | Install Network Points | 2018-06-06 09:00 A → 2018-06-01 09:00 (-5d) | 2018-06-06 15:00 A → 2018-06-01 15:00 (-5d) |  | 100% → 0% | none → 0.5d | baseline start 2018-06-06 09:00 → 2011-05-03 12:30; baseline finish 2018-06-06 15:00 → 2011-05-04 10:30 |
| 35 | Install Phone Connections | 2018-06-06 09:00 A → 2018-06-01 09:00 (-5d) | 2018-06-06 12:30 A → 2018-06-01 12:30 (-5d) |  | 100% → 0% | none → 0.5d | baseline start 2018-06-06 09:00 → 2011-05-03 12:30; baseline finish 2018-06-06 12:30 → 2011-05-03 17:00 |
| 36 | Re-Paint | 2018-06-07 09:00 A → 2018-06-02 07:00 (-5d) | 2018-06-09 11:00 A → 2018-06-02 15:00 (-7d) |  | 100% → 0% | none → 0d | baseline start 2018-06-07 09:00 → 2011-05-04 06:00; baseline finish 2018-06-09 11:00 → 2011-05-06 07:00 |
| 37 | Carpet | 2018-06-11 09:00 A → 2018-06-04 06:00 (-7d) | 2018-06-14 07:00 A → 2018-06-06 07:00 (-8d) |  | 100% → 0% | none → 0d | baseline start 2018-06-11 09:00 → 2011-05-07 07:00; baseline finish 2018-06-14 07:00 → 2011-05-07 15:00 |
| 38 | Install New Furniture | 2018-06-13 09:00 A → 2018-06-06 07:00 (-7d) | 2018-06-16 08:00 A → 2018-06-08 08:00 (-8d) |  | 100% → 0% | none → 0d | baseline start 2018-06-13 09:00 → 2011-05-09 06:00; baseline finish 2018-06-16 08:00 → 2011-05-11 07:00 |
| 39 | Install New PCs | 2018-06-15 09:00 A → 2018-06-08 09:00 (-7d) | 2018-06-15 17:00 A → 2018-06-08 17:00 (-7d) |  | 100% → 0% | none → 0.5d | baseline start 2018-06-15 09:00 → 2011-05-11 09:00; baseline finish 2018-06-15 17:00 → 2011-05-11 17:00 |
| 40 | Refit Office Complete | 2018-06-18 09:00 A → 2018-06-08 17:00 (-10d) | 2018-06-18 09:00 A → 2018-06-08 17:00 (-10d) |  | 100% → 0% | none → 0.5d | baseline start 2018-06-18 09:00 → 2011-05-11 17:00; baseline finish 2018-06-18 09:00 → 2011-05-11 17:00 |
| 41 | **Office Move** | 2018-06-04 09:00 → 2018-05-31 09:00 (-4d) | 2018-06-21 07:00 → 2018-06-14 07:00 (-7d) | 13d → 10d |  |  | baseline start 2018-06-04 09:00 → 2011-04-29 12:30; baseline finish 2018-06-21 07:00 → 2011-05-16 17:00 |
| 42 | Order packing boxes | 2018-06-04 09:00 → 2018-05-31 09:00 (-4d) | 2018-06-04 10:00 → 2018-05-31 10:00 (-4d) |  |  | 10.36d → 7.36d | baseline start 2018-06-04 09:00 → 2011-04-29 12:30; baseline finish 2018-06-04 10:00 → 2011-04-29 14:30 |
| 43 | Staff Pack | 2018-06-18 09:00 → 2018-06-11 09:00 (-7d) | 2018-06-18 12:30 → 2018-06-11 12:30 (-7d) |  |  |  | baseline start 2018-06-18 09:00 → 2011-05-12 09:00; baseline finish 2018-06-18 12:30 → 2011-05-12 12:30 |
| 44 | Staff Move | 2018-06-18 12:30 → 2018-06-11 12:30 (-7d) | 2018-06-21 07:00 → 2018-06-14 07:00 (-7d) |  |  |  | baseline start 2018-06-18 12:30 → 2011-05-12 12:30; baseline finish 2018-06-21 07:00 → 2011-05-14 11:00 |
| 45 | Office Move Complete | 2018-06-21 07:00 → 2018-06-14 07:00 (-7d) | 2018-06-21 07:00 → 2018-06-14 07:00 (-7d) |  |  |  | baseline start 2018-06-21 07:00 → 2011-05-16 17:00; baseline finish 2018-06-21 07:00 → 2011-05-16 17:00 |
